# 3GPP_Release-2000

Schedule from MS Project, 2000-01-03 to 2007-01-19, A marks actual dates.

## Calendars

- Standard: Mon-Fri 08:00-12:00, 13:00-17:00; Sat-Sun off.

## Resources

| Resource |
| --- |
| NP |
| N1 |
| N2 |
| N3 |
| N4 |
| N5 |
| TP |
| T1 |
| T2 |
| T3 |
| RP |
| R1 |
| R2 |
| R3 |
| R4 |
| SP |
| S1 |
| S2 |
| S3 |
| S4 |
| S5 |
| PCG |
| GP |
| No |
| CN4 |
| ? |
| WG G2 |
| G2 |
| G1 |
| G4 |
| G3 |
| All |
| Generic |
| MLST |
| G5 |
| S3; G2 |
| WG T2 |
| GP;G1 |
| G4;G5 |
| OMA |
| GP-G2 |
| Yes |
| GP; |
| N4; |
| GP; N1 |
| CT5 |
| C5 |
| C1 |
| C4 |
| C3 |
| C6 |
| G1; |
| 4 |
| ct |
| c;s;r |
| CT;RAN;SA |

## Schedule

| ID | WBS | Task | Type | Duration | Start | Finish | Complete | Remaining | Baseline start | Baseline finish | Baseline duration | Total slack | Constraint | Resources | Work | Actual work | Text9 | Text6 | Text1 | Text4 | Text5 | Text7 | Text8 |
| --- | --- | --- | --- | --- | --- | --- | --- | --- | --- | --- | --- | --- | --- | --- | --- | --- | --- | --- | --- | --- | --- | --- | --- |
| 1 | 1 | VERSION 2006 February 17th |  | 1d | 2000-01-03 | 2000-01-03 |  |  | 2000-01-03 | 2000-01-03 | 1d | 1839d |  |  |  |  | 2044 |  |  |  |  |  |  |
| 2 | 2 | "CTRL + a" to display all the 3GPP fields |  | 1d | 2000-01-03 | 2000-01-03 |  |  | 2000-01-03 | 2000-01-03 | 1d | 1839d |  |  |  |  | 1462 |  |  |  |  |  |  |
| 3 | 3 | Content of Release 7, not frozen |  | 1d | 2000-01-03 | 2000-01-03 |  |  | 2000-01-03 | 2000-01-03 | 1d | 1839d |  |  |  |  | 2058 |  |  |  |  |  |  |
| 5 | 4 | Rel-7 Features listed below |  | 1d? | 2000-01-03 | 2000-01-03 |  |  | 2000-01-03 | 2000-01-03 | 1d? | 1839d |  | CT;RAN;SA | 8h |  |  | Rel-7 |  |  |  |  |  |
| 6 | 8.5 | **Multiple Input Multiple Output antennas (MIMO)** |  | 850d? | 2003-03-14 A | 2006-06-15 | 17% | 707.36d? | 2003-03-14 | 2005-12-15 | 720d? | 156d |  | R1 | 30360h | 6052.8h | 2468 | Rel-7 | MIMO | Howard Huang, Lucent | hchuang@lucent.com | TSG | Cesar |
| 7 | 5.1 | MIMO - Physical layer |  | 720d? | 2003-09-12 A | 2006-06-15 | 65% | 252d? | 2003-09-12 | 2005-12-15 | 590d? | 156d | finish no earlier than 2006-06-15 | R1 | 5760h | 3744h |  | Rel-7 | MIMO-Phys | Howard Huang, Lucent | hchuang@lucent.com | TSG | MCC_RAN |
| 8 | 5.2 | MIMO - Layer 2,3 aspects |  | 720d? | 2003-09-12 | 2006-06-15 |  |  | 2003-09-12 | 2005-12-15 | 589d? | 156d | finish no earlier than 2006-06-15 | R2 | 5760h |  |  | Rel-7 | MIMO-L23 | Howard Huang, Lucent | hchuang@lucent.com | TSG | MCC_RAN |
| 9 | 5.3 | MIMO - Iub/Iur Protocol Aspects |  | 850d? | 2003-03-14 | 2006-06-15 |  |  | 2003-03-14 | 2005-12-15 | 719d? | 156d | finish no earlier than 2006-06-15 | R3 | 6800h |  |  | Rel-7 | MIMO-IurIub | Howard Huang, Lucent | hchuang@lucent.com | TSG | MCC_RAN |
| 10 | 5.4 | MIMO - RF Radio Transmission/Reception, System Performance Requirements and Conformance Testing |  | 655d? | 2003-12-12 A | 2006-06-15 | 4% | 628.8d? | 2003-12-12 | 2005-12-15 | 524d? | 156d | finish no earlier than 2006-06-15 | R4 | 5240h | 209.6h |  | Rel-7 | MIMO-RF | Man Hung Ng, Lucent | ngm@lucent.com | TSG | MCC_RAN |
| 11 | 6 | **Rel-7 Improvements of the Radio Interface** |  | 588d? | 2004-09-15 A | 2006-12-15 | 60% | 233.05d? | 2004-09-15 | 2006-06-15 | 456d? | 25d |  | RP | 19832h | 11184.3h |  | Rel-7 | RInImp |  |  |  | Cesar |
| 12 | 6.1 | UMTS 2.6 GHz |  | 195d? | 2004-09-15 A | 2005-06-14 A | 100% |  | 2004-09-15 | 2005-06-14 | 195d? |  | finish no earlier than 2005-06-14 | R4 | 1560h | 1560h |  | Rel-7 | RInImp-UMTS2600 | Jussi Numminen, Nokia | jussi.numminen@nokia.com | TSG | Cesar |
| 13 | 6.2 | UMTS 2.6 GHz TDD |  | 261d? | 2004-12-15 A | 2005-12-14 A | 100% |  | 2004-12-15 | 2005-12-15 | 261d? |  | finish no earlier than 2005-12-15 | R4 | 2088h | 2088h |  | Rel-7 | RInImp-UMTS2600TDD | Shin Horng Wong (IPWireless) | shwong@IPWIRELESS.COM | TSG | MCC_RAN |
| 14 | 6.3 | UMTS 900 MHz |  | 261d? | 2004-12-15 A | 2005-12-14 A | 100% |  | 2004-12-15 | 2005-12-15 | 261d? |  | finish no earlier than 2005-12-15 | R4 | 2088h | 2088h |  | Rel-7 | RInImp-UMTS900 | Yannick Li (Nortel) | yli@nortelnetworks.com | TSG | MCC_RAN |
| 15 | 6.4 | UMTS 1700 MHz |  | 197d? | 2005-03-15 A | 2005-12-14 A | 100% |  | 2005-03-15 | 2005-12-15 | 197d? |  | finish no earlier than 2005-12-15 | R4 | 1576h | 1576h |  | Rel-7 | RInImp-UMTS1700 | Takehiro Nakamura | NTT DoCoMo | TSG | MCC_RAN |
| 16 | 6.5 | Pending decision of the PCG!! UMTS 2.6 GHz FDD DL External |  | 195d? | 2005-09-15 | 2006-06-15 |  |  | 2005-09-15 | 2006-06-15 | 195d? | 157d | finish no earlier than 2006-06-15 | R4 | 1560h |  |  | Rel-7 | RInImp-UMTS2600Ext | Han van Bussel | han.van.bussel@t-mobile.de | TSG | MCC_RAN |
| 17 | 6.6 | UE Antenna Performance Evaluation Method and Requirements |  | 325d? | 2004-12-15 A | 2006-03-15 | 55% | 146.25d? | 2004-12-15 | 2006-03-15 | 325d? | 223d | finish no earlier than 2006-03-15 | R4 | 2600h | 1430h |  | Rel-7 | RInImp-UEAnt | Christian Bergljung (TeliaSonera) | Christian.Bergljung@TeliaSonera.com | TSG | MCC_RAN |
| 18 | 6.7 | Improved Performance Requirements for HSDPA UE based on Rx Diversity (type 1) & LMMSE equalizer (type 2) | milestone | 0d? | 2005-03-15 A | 2005-03-15 | 50% | 0d? | 2005-03-15 | 2005-03-15 | 0d? | 484d | finish no earlier than 2005-03-15 | R4 |  |  |  | Rel-7 | RInImp-HSPerf-Type3 | Marc Grant | marc.grant@cingular.com | TSG | MCC_RAN |
| 19 | 6.8 | Improved Performance Requirements for non-HSDPA channels based on Enhanced Receiver, Type 1 (Rx Diversity) |  | 195d? | 2005-09-15 A | 2006-06-15 | 25% | 146.25d? | 2005-09-15 | 2006-06-15 | 195d? | 157d | finish no earlier than 2006-06-15 | R4 | 1560h | 390h |  | Rel-7 | RInImp-DCHPerf-RxDiv | Marc Grant | marc.grant@cingular.com | TSG | MCC_RAN |
| 20 | 6.9 | Improved support of gaming over HSDPA/EDCH |  | 262d? | 2005-12-15 | 2006-12-15 |  |  |  |  |  | 25d | finish no earlier than 2006-12-15 | R2 | 2096h |  |  | Rel-7 | RInImp-Gaming | Don Zelmer, Cingular | don.zelmer@cingular.com |  | MCC_RAN |
| 21 | 7 | **7.68Mcps TDD option** |  | 391d? | 2004-09-15 A | 2006-03-15 | 68% | 125.12d? | 2004-09-15 | 2006-06-15 | 456d? | 222d |  | RP | 18768h | 12013.4h |  | Rel-7 | VHCRTDD | Martin Beale, IPWireless | mbeale@ipwireless.com | TSG | Cesar |
| 22 | 7.1 | VHCRTDD: Stage 2 |  | 391d? | 2004-09-15 A | 2006-03-15 | 90% | 39.1d? | 2004-09-15 | 2005-12-15 | 326d? | 222d | finish no earlier than 2006-03-15 | R1 | 3128h | 2815.2h |  | Rel-7 | VHCRTDD-Stage2 | Martin Beale, IPWireless | mbeale@ipwireless.com | TSG | MCC_RAN |
| 23 | 7.2 | VHCRTDD: Physical Layer |  | 391d? | 2004-09-15 A | 2006-03-15 | 90% | 39.1d? | 2004-09-15 | 2005-12-15 | 326d? | 222d | finish no earlier than 2006-03-15 | R1 | 3128h | 2815.2h |  | Rel-7 | VHCRTDD-Phys | Martin Beale, IPWireless | mbeale@ipwireless.com | TSG | MCC_RAN |
| 24 | 7.3 | VHCRTDD: Layer 2 and layer 3 protocol aspects |  | 391d? | 2004-09-15 A | 2006-03-15 | 50% | 195.5d? | 2004-09-15 | 2005-12-15 | 326d? | 222d | finish no earlier than 2006-03-15 | R2 | 3128h | 1564h |  | Rel-7 | VHCRTDD-L23 | Derek Richards, IPWireless | drichards@ipwireless.com | TSG | MCC_RAN |
| 25 | 7.4 | VHCRTDD: UTRAN Iub/Iur Protocol Aspects |  | 391d? | 2004-09-15 A | 2006-03-15 | 50% | 195.5d? | 2004-09-15 | 2005-12-15 | 326d? | 222d | finish no earlier than 2006-03-15 | R3 | 3128h | 1564h |  | Rel-7 | VHCRTDD-IurIub | Peter Legg, IPWireless | plegg@ipwireless.com | TSG | MCC_RAN |
| 26 | 7.5 | VHCRTDD: RF Radio Transmission/ Reception, System Performance Requirements and Conformance Testing |  | 391d? | 2004-09-15 A | 2006-03-15 | 60% | 156.4d? | 2004-09-15 | 2006-06-15 | 456d? | 222d | finish no earlier than 2006-03-15 | R4 | 3128h | 1876.8h |  | Rel-7 | VHCRTDD-RF | Shin Horng Wong | shwong@ipwireless.com | TSG | MCC_RAN |

Notes:
- 6: Text3: TR25.876,TR25.996
- 7: Text3: 25.211, 25.212, 25.213, 25.214, 25.215, 25.221, 25
- 8: Text3: TR 25.876
- 12: Approved at RP#25 as RP-040377 / Text3: TS25.101, TS25.104, TS25.133, TS25.141, TS25.331, TS25.942, TS25.306, TS25.307, TS34.121
- 13: Text3: 25.102, 25.105, 25.113, 25.123, 25.142, 25.331, 25.942, 25.306, 25.307, 34.122, 34.124
- 14: Text3: 25.101, 25.104, 25.113, 25.133, 25.141, 25.331, 25.942, 25.306, 25.307, 34.121
- 15: Text3: 25.101, 25.104, 25.113, 25.133, 25.141, 25.306, 25.307, 25.331, 34.121
- 16: Text3: 25.101, 25.104, 25.133, 25.141, 25.331, 25.942, 25.306, 25.307, 34.121
- 17: Text3: TS25.101
- 18: Text3: 25.101
- 19: Text3: 25.101
- 21: Approved at RP#25 as RP-040365
- 22: Text3: New specification
- 23: Text3: TS25.221, TS25.222, TS25.223, TS25.224,TS25.225
- 24: Text3: TS25.301, TS25.302, TS25.305, TS25.306, TS25.321, TS25.331
- 25: Text3: TS25.401, TS25.420, TS25.423, TS25.425, TS25.427, TS25.430, TS25.433, TS25.435
- 26: Text3: TS25.102, TS25.105, TS25.123, TS25.133, TS25.142

| ID | WBS | Task | Type | Duration | Start | Finish | Complete | Remaining | Baseline start | Baseline finish | Baseline duration | Total slack | Constraint | Resources | Work | Actual work | Text1 | Text6 | Text7 | Text8 | Text4 | Text5 | Text2 | Text9 | Text12 |
| --- | --- | --- | --- | --- | --- | --- | --- | --- | --- | --- | --- | --- | --- | --- | --- | --- | --- | --- | --- | --- | --- | --- | --- | --- | --- |
| 27 | 8 | **Rel-7 RAN improvements** |  | 392d? | 2004-12-15 A | 2006-06-15 | 45% | 214.66d? | 2004-12-15 | 2006-03-15 | 325d? | 156d |  | RP | 11000h | 4250.05h | RANimp | Rel-7 | TSG | Cesar |  |  |  |  |  |
| 28 | 8.1 | Optimisation of channelisation code utilisation for 1.28 Mcps TDD |  | 326d? | 2004-12-15 A | 2006-03-15 | 70% | 97.8d? | 2004-12-15 | 2005-12-15 | 261d? | 222d | finish no earlier than 2006-03-15 | R1 | 2608h | 1825.6h | RANimp-RABSE-CodOptLCRTDD | Rel-7 | TSG | MCC_RAN | Ka Leong Lo | kaleong.lo@utstar.com |  |  |  |
| 29 | 8.2 | Delay optimisation for procedures applicable to CS and PS Connections |  | 328d? | 2005-03-15 A | 2006-06-15 | 20% | 262.4d? | 2005-03-15 | 2006-03-15 | 261d? | 156d | finish no earlier than 2006-06-15 | R2 | 2624h | 524.8h | RANimp-DelayOpt | Rel-7 | TSG | MCC_RAN | Juho Pirskanen | juho.pirskanen@nokia.com |  |  |  |
| 30 | 8.3 | UE Performance Requirements for MBMS (TDD) |  | 261d? | 2005-03-15 A | 2006-03-15 | 50% | 130.5d? | 2005-03-15 | 2006-03-15 | 261d? | 223d | finish no earlier than 2006-03-15 | R4 | 2088h | 1044h | MBMS-RAN-RF-TDD | Rel-7 | TSG | MCC_RAN | Shin Horng Wong | shwong@ipwireless.com |  |  |  |
| 31 | 8.4 | Continuous connectivity for packet data users |  | 68d? | 2005-03-14 A | 2005-06-15 | 30% | 47.6d? | 2005-03-14 | 2005-03-15 | 1d? | 417d | finish no earlier than 2005-06-15 | R1 | 544h | 163.2h | RANimp-CoCoPack | Rel-7 | TSG | MCC_RAN | Joerg Gustrau | joerg.gustrau@siemens.com |  |  |  |
| 32 | 9 | **3.84 Mcps TDD Enhanced Uplink** |  | 327d? | 2005-03-15 A | 2006-06-15 | 41% | 194.56d? | 2005-03-15 | 2006-06-15 | 327d? | 157d |  | RP | 13072h | 4666.03h | EDCHTDD | Rel-7 | TSG | Cesar | Nicholas Anderson | nanderson@ipwireless.com |  |  |  |
| 33 | 9.1 | EDCHTDD: Stage 2 |  | 197d? | 2005-03-15 A | 2005-12-14 | 60% | 78.8d? | 2005-03-15 | 2005-12-14 | 197d? | 287d | start no earlier than 2005-03-15 | R2 | 1576h | 945.6h | EDCHTDD-Stage2 | Rel-7 | TSG | MCC_RAN | Nicholas Anderson | nanderson@ipwireless.com |  |  |  |
| 34 | 9.2 | EDCHTDD: Physical Layer |  | 261d? | 2005-03-15 A | 2006-03-14 | 60% | 104.4d? | 2005-03-15 | 2006-03-14 | 261d? | 223d | start no earlier than 2005-03-15 | R1 | 2088h | 1252.8h | EDCHTDD-Phys | Rel-7 | TSG | MCC_RAN | Nicholas Anderson | nanderson@ipwireless.com |  |  |  |
| 35 | 9.3 | EDCHTDD: Layer 2 and 3 Protocol Aspects |  | 261d? | 2005-03-15 A | 2006-03-14 | 60% | 104.4d? | 2005-03-15 | 2006-03-14 | 261d? | 223d | start no earlier than 2005-03-15 | R2 | 2088h | 1252.8h | EDCHTDD-L23 | Rel-7 | TSG | MCC_RAN | Derek Richards | drichards@ipwireless.com |  |  |  |
| 36 | 9.4 | EDCHTDD: UTRAN Iub/Iur Protocol Aspects |  | 261d? | 2005-03-15 A | 2006-03-14 | 25% | 195.75d? | 2005-03-15 | 2006-03-14 | 261d? | 223d | start no earlier than 2005-03-15 | R3 | 2088h | 522h | EDCHTDD-IurIub | Rel-7 | TSG | MCC_RAN | Jim Miller | jim.miller@interdigital.com |  |  |  |
| 37 | 9.5 | EDCHTDD: RF Radio Transmission/ Reception, System Performance Requirements and Conformance Testing |  | 327d? | 2005-03-15 A | 2006-06-15 | 10% | 294.3d? | 2005-03-15 | 2006-06-15 | 327d? | 157d | finish no earlier than 2006-06-15 | R4 | 2616h | 261.6h | EDCHTDD-RF | Rel-7 | TSG | MCC_RAN | Shin Horng Wong | shwong@ipwireless.com |  |  |  |
| 38 | 10 | **PS domain and IMS impacts for supporting IMS Emergency calls** |  | 1565d? | 2000-09-18 A | 2006-09-15 | 73% | 425.31d? | 2000-08-14 | 2006-06-09 | 1520d? | 90d |  | S2 | 38037h | 26797.5h | EMC1 | Rel-7 | TSG | Maurice | Rainer Liebhart |  |  |  |  |
| 39 | 10.1.1 | Service Requirements for IP-based emergency calls |  | 985d | 2000-09-18 A | 2004-06-25 A | 100% |  | 2000-09-18 | 2004-06-25 | 985d |  | finish no earlier than 2004-06-25 | S1 | 7880h | 7880h | EMC1 | Rel-7 |  |  |  |  | CCaR | 1314 |  |
| 40 | 10.2 | Study on Stage 2 for IMS-level solution |  | 668d? | 2003-02-26 A | 2005-09-16 A | 100% |  | 2003-02-26 | 2005-09-16 | 668d? |  | finish no earlier than 2005-09-16 | S2 | 5344h | 5344h | EMC1 | Rel-7 | TSG |  | Rainer Liebhart, Siemenws |  |  |  |  |
| 41 | 10.3 | Study on Stage 2 for GPRS-level solution |  | 301d? | 2004-10-14 A | 2005-12-08 A | 100% |  | 2004-10-14 | 2005-12-08 | 301d? |  | finish no earlier than 2005-12-08 | S2 | 2408h | 2408h | EMC1 | Rel-7 |  |  |  |  |  |  |  |
| 42 | 10.4 | Stage 2 Specification Phase - IMS-level |  | 200d? | 2005-09-05 A | 2006-06-09 | 64% | 72d? | 2005-09-05 | 2006-06-09 | 200d? | 160d | finish no earlier than 2006-06-09 | S2 | 1600h | 1024h | EMC1 | Rel-7 |  |  |  |  |  |  |  |
| 43 | 10.5 | Stage 2 Specification Phase - GPRS-level |  | 200d? | 2005-09-05 A | 2006-06-09 | 64% | 72d? | 2005-09-05 | 2006-06-09 | 200d? | 160d | finish no earlier than 2006-06-09 | S2 | 1600h | 1024h | EMC1 | Rel-7 |  |  |  |  |  |  |  |
| 44 | 10.1 | **Emergency Call Enhancements for IP& PS Based Calls – stage 3** |  | 180d | 2006-01-09 | 2006-09-15 |  |  | 2000-08-14 | 2005-07-11 | 1280.1d | 90d |  | C1 | 6684.96h |  | EMC1 | Rel-7 |  |  | Alf Heidermark (Ericsson) | alf.heidermark@ericsson.com | CCaR | 1653 |  |
| 45 | 10.1.2 | CT1 IMS aspects to support IMS Emergency sessions |  | 155.82d | 2006-01-09 | 2006-09-15 |  |  | 2000-10-17 | 2005-07-08 | 1209d | 90d | finish no earlier than 2006-09-15 | C1 | 1246.56h |  | EMC1 | Rel-7 |  |  | Mr Atle Monrad, Ericsson | Atle.Monrad@eto.ericsson.se | CCaR | 1315 |  |
| 46 | 10.1.2 | CT3 IMS aspects to support IMS Emergency sessions |  | 95d | 2006-05-08 | 2006-09-15 |  |  | 2000-10-17 | 2005-07-08 | 1209d | 90d | finish no earlier than 2006-09-15 | C3 | 760h |  | EMC1 | Rel-7 |  |  | Mr Atle Monrad, Ericsson | Atle.Monrad@eto.ericsson.se | CCaR | 1315 |  |
| 47 | 10.1.5 | CT1 PS domain aspects to support IMS Emergency sessions |  | 154.9d | 2006-01-09 | 2006-09-15 |  |  | 2000-08-14 | 2005-07-11 | 1255d | 90d | start no earlier than 2006-01-09 | C1 | 1239.2h |  | EMC1 | Rel-7 |  |  | Mr Atle Monrad, Ericsson | Atle.Monrad@eto.ericsson.se | CCaR | 1646 |  |
| 48 | 10.1.5 | CT3 PS domain aspects to support IMS Emergency sessions |  | 95d | 2006-05-08 | 2006-09-15 |  |  | 2000-08-14 | 2005-07-11 | 1255d | 90d | start no earlier than 2006-05-08 | C3 | 760h |  | EMC1 | Rel-7 |  |  | Mr Atle Monrad, Ericsson | Atle.Monrad@eto.ericsson.se | CCaR | 1646 |  |
| 49 | 10.1.5 | CT4 PS domain aspects to support IMS Emergency sessions |  | 180d | 2006-01-09 | 2006-09-15 |  |  | 2000-08-14 | 2005-07-11 | 1255d | 90d | start no earlier than 2006-01-09 | C4 | 1440h |  | EMC1 | Rel-7 |  |  | Mr Atle Monrad, Ericsson | Atle.Monrad@eto.ericsson.se | CCaR | 1646 |  |
| 50 | 11 | **Access Class Barring and Overload Protection** |  | 492d? | 2004-03-15 A | 2006-01-31 | 50% | 244.33d? | 2004-03-15 | 2005-11-18 | 440d? | 253d |  | S2 | 11024h | 5549.33h | ACBOP | Rel-7 | TSG | Maurice | Chris Pudney, Vodafone |  |  |  |  |
| 51 | 11.1 | TR on Stage 2 |  | 274d? | 2004-03-15 A | 2005-03-31 A | 100% |  | 2004-03-15 | 2005-03-31 | 274d? |  | finish no earlier than 2005-03-31 | S2 | 2192h | 2192h | ACBOP | Rel-7 | TSG |  |  |  |  |  |  |
| 52 | 11.2 | Extra ACBOP information in GERAN |  | 440d? | 2004-03-15 | 2005-11-18 |  |  | 2004-03-15 | 2005-11-18 | 440d? | 305d | finish no earlier than 2005-11-18 | GP | 3520h |  | ACBOP | Rel-7 | TSG | Gert |  |  |  |  |  |
| 53 | 11.3 | Stage 3 CN aspects of ACBOP |  | 172d? | 2005-06-06 A | 2006-01-31 A | 100% |  | 2004-12-08 | 2004-12-08 | 1d? |  | start no earlier than 2005-06-06 | C1 | 1376h | 1376h | ACBOP | Rel-7 |  |  |  |  |  |  |  |
| 54 | 11.4 | Deleted - Potential impact on Iu interface Overload functionality | milestone | 0d? | 2004-03-15 A | 2004-03-15 A | 100% |  | 2004-03-15 | 2004-03-15 | 0d? |  | finish no earlier than 2004-03-15 | RP |  |  | ACBOP | Rel-7 |  |  |  |  |  |  | RP-25 |
| 55 | 11.5 | Deleted - Extra ACBOP information in RAN | milestone | 0d? | 2004-03-15 A | 2004-03-15 A | 100% |  | 2004-03-15 | 2004-03-15 | 0d? |  | finish no earlier than 2004-03-15 | RP |  |  | ACBOP | Rel-7 |  |  |  |  |  |  | RP-25 |

Notes:
- 27: Generic feature
- 29: Text3: TS25.321, TS25.322, TS25.331
- 30: Text3: TS25.102, TS25.123
- 34: Text3: TS25.201, TS25.221,TS25.222, TS25.223, TS25.224, TS25.225
- 35: Text3: TS25.301, TS25.302, TS25.306, TS25.321, TS25.331
- 36: Text3: TS25.401, TS25.420, TS25.423, TS25.427, TS25.430, TS25.433, TS25.435
- 37: Text3: TS25.102, TS25.105, TS25.123, TS25.142
- 39: Text3: 22.976
- 40: Text3: 23.228, 23.060, 23.002
- 45: Text3: 24.229
- 46: Text3: 29.613
- 47: Text3: 24.008
- 48: Text3: 29.061
- 49: Text3: 29.060
- 50: Text3: 23.898
- 52: Text3: 44.018
- 53: NEW - inserted on 2/9/2004 / Text3: 24.008
- 54: Text3: 25.413
- 55: Text3: 25.331

| ID | WBS | Task | Duration | Start | Finish | Complete | Remaining | Baseline start | Baseline finish | Baseline duration | Total slack | Constraint | Resources | Work | Actual work | Text1 | Text6 | Text7 | Text8 | Text5 |
| --- | --- | --- | --- | --- | --- | --- | --- | --- | --- | --- | --- | --- | --- | --- | --- | --- | --- | --- | --- | --- |
| 56 | 12 | **USSD message delivery and transfer to USIM** | 376d? | 2004-03-05 A | 2005-08-12 A | 100% |  | 2004-03-05 | 2005-11-16 | 443.7d? |  |  | S1 | 5698.4h | 5698.4h | USSD-USIM | Rel-7 | TSG | Michael |  |
| 57 | 12.1 | Stage 1 | 152d? | 2004-03-18 A | 2004-10-15 A | 100% |  | 2004-03-18 | 2004-10-15 | 152d? |  | start no earlier than 2004-03-18 | S1 | 1216h | 1216h | USSD-USIM | Rel-7 | TSG | Michael |  |
| 58 | 12.2 | Alignment with requirements regarding USSD usage | 193.3d? | 2004-03-05 A | 2005-08-12 A | 100% |  | 2004-03-05 | 2005-11-16 | 261d? |  | finish no earlier than 2005-08-12 | C6 | 1546.4h | 1546.4h | USSD-USIM | Rel-7 | TSG |  | cdubois@axalto.com |
| 59 | 13 | **Location Services enhancements Rel-7** | 548d? | 2004-06-28 A | 2006-08-02 | 58% | 228.09d? | 2004-06-28 | 2006-08-25 | 565d? | 122d |  | S2 | 29533.6h | 15312.5h | LCS3 | Rel-7 |  | Maurice |  |
| 60 | 13.1 | Global Stage 2 for LCS3 (including IMS emergency location aspects) | 321d? | 2004-12-31 A | 2006-03-24 | 95% | 17d? | 2004-12-31 | 2006-03-24 | 321d? | 215d | finish no earlier than 2006-03-24 | S2 | 2568h | 2432h | LCS3 | Rel-7 | TSG | Maurice | brodilitz@sirf.com |
| 61 | 13.2 | CT4 aspects for LCS | 66d? | 2006-01-02 A | 2006-04-03 | 35% | 43d? | 2005-03-15 | 2005-06-15 | 66d? | 209d | start no earlier than 2006-01-01 | C4 | 528h | 184h | LCS3-UEPos-LBS | Rel-7 | TSG |  |  |
| 62 | 13.3 | **LCS for 3GPP Interworking WLAN** | 548d? | 2004-06-28 A | 2006-08-02 | 66% | 188.86d? | 2004-06-28 | 2006-08-25 | 565d? | 122d |  | S1 | 9885.6h | 3704h | LCS3-IWLAN | Rel-7 | TSG | Michael |  |
| 63 | 13.3.1 | FS on 3GPP system to WLAN Interworking with LCS | 512.7d? | 2004-06-28 A | 2006-06-30 | 79% | 107d? | 2004-06-28 | 2005-09-29 | 316.7d? | 145d | finish no earlier than 2005-09-29 | S1 | 4101.6h | 3245.6h | LCS3-IWLAN | Rel-7 |  |  |  |
| 64 | 13.3.2 | Stage 2 work on an LCS architecture for I-WLAN. | 175d? | 2005-12-01 A | 2006-08-02 | 26% | 130d? |  |  |  | 122d | start no earlier than 2005-12-01 | S2 | 1400h | 360h | LCS3-IWLAN | Rel-7 |  | Maurice | dhshim@lge.com ; phede@lge.com |
| 65 | 13.4 | **UE positioning Rel-7** | 457d? | 2004-09-15 A | 2006-06-15 | 62% | 172.99d? | 2004-09-15 | 2006-06-15 | 456d? | 156d |  | RP | 8352h | 5629.24h | LCS3-UEpos | Rel-7 | TSG | Cesar |  |
| 66 | 13.4.1 | Inclusion of Uplink TDOA UE positioning method in the UTRAN specifications | 456d? | 2004-09-15 A | 2006-06-15 | 80% | 91.2d? | 2004-09-15 | 2006-06-15 | 456d? | 157d | finish no earlier than 2006-06-15 | R2 | 3648h | 2918.4h | LCS3-UEPos-UTDOA | Rel-7 | TSG | MCC_RAN | rlgross@trueposition.com |
| 67 | 13.4.2 | Global Navigation Satellite System (GNSS) in UTRAN | 131d? | 2005-12-15 | 2006-06-15 |  |  |  |  |  | 156d | finish no earlier than 2006-06-15 | R2 | 1048h |  |  | Rel-7 |  | MCC_RAN | alain.abinakhoul@francetelecom.com |
| 68 | 13.5 | **LCS Enhancements Related to Location-Based Services** | 66d? | 2005-03-15 A | 2005-06-15 | 50% | 33d? | 2005-03-15 | 2005-06-15 | 66d? | 418d |  | R2 | 1056h | 528h | LCS3-UEPos-LBS | Rel-7 | TSG | MCC_RAN | BRodilitz@SiRF.com |
| 69 | 13.5.1 | RAN2 aspects for LBS | 66d? | 2005-03-15 A | 2005-06-15 | 50% | 33d? | 2005-03-15 | 2005-06-15 | 66d? | 418d | finish no earlier than 2005-06-15 | R2 | 528h | 264h | LCS3-UEPos-LBS | Rel-7 | TSG | MCC_RAN | BRodilitz@SiRF.com |
| 70 | 13.6 | LCS Enhancements Related to Location-Based Services | 345d? | 2005-01-03 A | 2006-04-28 | 10% | 310.5d? | 2005-01-03 | 2006-04-07 | 330d? | 190d | finish no earlier than 2006-04-28 | GP | 2760h | 276h | LCS3-LBS | Rel-7 | TSG | Paolo | kjudge@sirf.com |
| 71 | 14 | **Advanced Global Navigation Satellite System (A-GNSS) concept** | 503d? | 2004-06-28 A | 2006-05-31 | 25% | 376.39d? | 2004-06-28 | 2006-04-14 | 470d? | 167d |  | S1 | 11305.6h | 1983.28h | LCS3-AGNSS | Rel-7 | TSG | Michael | Michel.monnerat@space.alcatel.fr |
| 72 | 14.1 | Support for GNSS in GERAN | 451.2d? | 2004-06-28 A | 2006-04-14 | 5% | 428.64d? | 2004-06-28 | 2006-04-14 | 451.2d? | 200d | finish no earlier than 2006-04-14 | GP | 3609.6h | 180.48h | AGNSS-GP | Rel-7 | TSG | Paolo | richard.couty@space.alcatel.fr |
| 73 | 14.2 | Towards A-GNSS Concept | 459d? | 2004-08-27 A | 2006-05-31 | 45% | 252.45d? | 2004-08-27 | 2005-09-29 | 285d? | 167d | finish no earlier than 2005-09-29 | S1 | 3672h | 1652.4h | GNSS | Rel-7 | TSG | Paolo | richard.couty@space.alcatel.fr |
| 74 | 15 | **Combinational Services** | 296d? | 2005-01-17 A | 2006-03-06 | 96% | 10.52d? | 2005-01-17 | 2005-12-07 | 233d? | 229d |  | S1 | 7544h | 7275.82h | CSICS | Rel-7 | TSG | Michael | Robert.Frank@teliasonera.com |
| 75 | 15.1 | Stage 1 for CSICS | 104d? | 2005-01-17 A | 2005-06-09 A | 100% |  | 2005-01-17 | 2005-06-09 | 104d? |  | start no earlier than 2005-01-17 | S1 | 832h | 832h | CSICS | Rel-7 | TSG |  |  |
| 76 | 15.2 | Stage 2 for CSICS | 130d? | 2005-01-17 A | 2005-07-15 A | 100% |  | 2005-01-17 | 2005-07-15 | 130d? |  | start no earlier than 2005-01-17 | S2 | 1040h | 1040h | CSICS | Rel-7 |  |  |  |
| 77 | 15.3 | Stage 3 for CSICS CN aspects | 221d? | 2005-05-02 A | 2006-03-06 | 90% | 23d? | 2005-05-02 | 2005-10-28 | 130d? | 229d | finish no earlier than 2006-03-06 | C1 | 1768h | 1584h | CSICS | Rel-7 | TSG | Andrijana |  |
| 78 | 15.4 | Stage 3 for codec aspects - check if really completed | 192d? | 2005-03-15 A | 2005-12-07 A | 100% |  | 2005-03-15 | 2005-12-07 | 192d? |  | finish no earlier than 2005-12-07 | S4 | 1536h | 1536h | CSICS-Codec | Rel-7 | TSG | Paolo | Per.Frojdh@ericsson.com |
| 79 | 16 | Enhancement of E2E QoS | 336.4d? | 2004-06-28 A | 2005-12-01 A | 100% |  | 2004-06-28 | 2005-12-01 | 336.4d? |  | finish no earlier than 2005-12-01 | S2 | 2691.2h | 2691.2h | QoS7 | Rel-7 | TSG | Maurice |  |

Notes:
- 56: Text3: 22.090
- 57: Text3: 22.090
- 58: Text4: Christophe Dubois (Axalto)
- 59: Text3: 23.271
- 60: Approved SA#27. Appropriate place forEmergency work to be found / Text3: 23.271 / Text4: Ben Rodilitz, SiRF
- 61: Reminded by e-mail from Hannu on 19/12/05
- 62: Text3: 22.935 / Text4: Mike Loushine, (Telcordia)
- 63: DAB - Should be SA1 / Text3: 22.935
- 64: Approved in SP#29 / Text3: 23.8yz / Text4: Donghee Shim (LG Electronics Inc.); Patrice HÉDÉ (LG Electronics Mobilecomm France)
- 66: Text3: TS25.305, TS25.453 / Text4: Robert Gross, TruePosition
- 67: Text3: TS 25.305,TS 25.331,TS 25.306,TS 25.413,TS 25.423,TS 25.433,TS 25.453,TS 25.171,TS 34.171 / Text4: Alain Abinakhoul, France Telecom
- 68: Text3: 25.305, 25.331, 25.410, 25.413, 25.453 / Text4: Ben Rodilitz
- 69: Text3: 25.305, 25.331, 25.410, 25.413, 25.453 / Text4: Ben Rodilitz
- 70: Linked SP-040682 / Text3: 43.059, 44.031, 48.008, 49.031 / Text4: Kevin Judge, SiRF Technologies
- 71: Text4: Michel MONNERAT
- 72: Started / Text4: Richard Couty, ALCATEL SA
- 73: Text4: Richard Couty, ALCATEL SA
- 74: Text4: Robert Frank, TeliaSonera
- 75: Text3: 22.279
- 76: Text3: 23.279
- 77: Text3: 24.229, 24.008 / Text4: Peter Dawes (Vodafone)
- 78: Started / Text3: TS 26.141, 26.235, 26.236 / Text4: Per Fröjdh, Ericsson
- 79: DAB - pushed back to June / Text3: 23.802

| ID | WBS | Task | Type | Duration | Start | Finish | Complete | Remaining | Baseline start | Baseline finish | Baseline duration | Total slack | Constraint | Resources | Work | Actual work | Text1 | Text6 | Text7 | Text8 | Text3 | Text4 | Text5 |
| --- | --- | --- | --- | --- | --- | --- | --- | --- | --- | --- | --- | --- | --- | --- | --- | --- | --- | --- | --- | --- | --- | --- | --- |
| 80 | 17 | **System enhancements for fixed broadband access to IMS** |  | 823d? | 2003-11-05 A | 2006-12-29 | 47% | 435.34d? | 2004-08-03 | 2005-12-08 | 353d? | 15d |  | S2 | 31497.6h | 11293.3h | FBI | Rel-7 | TSG | Maurice |  |  |  |
| 81 | 17.1 | **TISPAN Rel 1 related aspects** |  | 611d? | 2003-11-05 A | 2006-03-08 | 65% | 216.8d? |  |  |  | 227d |  | S2 | 19856h | 9485.33h | FBI |  |  |  |  |  |  |
| 82 | 17.1.1 | Stage 2 of FBI for TISPAN R1 |  | 365d? | 2004-10-14 A | 2006-03-08 | 87% | 48d? |  |  |  | 227d | start no earlier than 2004-10-14 | S2 | 2920h | 2536h | FBI |  |  | Maurice |  |  |  |
| 83 | 17.1.2 | **Protocol impact of FBI for TISPAN R1** |  | 541d? | 2003-11-05 A | 2005-11-30 | 58% | 225.42d? | 2004-08-03 | 2005-11-30 | 347d? | 297d |  | C1 | 11104h | 6477.33h | FBI | Rel-7 | TSG | Andrijana | new TR 24.819, 24.229, 29.229, 29.163, 29.209 | Peter Leis (Siemens) |  |
| 84 | 17.1.2.1 | CT1 aspects of FBI for TISPAN R1 |  | 347d? | 2004-08-03 A | 2005-11-30 | 85% | 52.05d? | 2004-08-03 | 2005-11-30 | 347d? | 297d | finish no earlier than 2005-03-03 | C1 | 2776h | 2359.6h | FBI | Rel-7 | TSG | Andrijana | new TR 24.819, 24.229, 29.229, 29.163, 29.209 | Siemens |  |
| 85 | 17.1.2.2 | CT3 aspects of FBI for TISPAN R1 |  | 347d? | 2003-11-05 A | 2005-03-03 | 90% | 34.7d? | 2004-08-03 | 2005-11-30 | 347d? | 491d | finish no earlier than 2005-03-03 | C3 | 2776h | 2498.4h | FBI | Rel-7 | TSG | Andrijana | new TR, 29.229, 29.163 | Siemens |  |
| 86 | 17.1.2.3 | CT4 aspects of FBI for TISPAN R1 |  | 347d? | 2003-11-05 | 2005-03-03 |  |  | 2004-08-03 | 2005-11-30 | 347d? | 491d | finish no earlier than 2005-03-03 | C4 | 2776h |  | FBI | Rel-7 | TSG | Andrijana | 29.209 | Siemens |  |
| 87 | 17.1.3 | Security Enhancements for FBI |  | 118d? | 2005-06-28 A | 2005-12-08 | 50% | 59d? | 2005-06-28 | 2005-12-08 | 118d? | 291d | start no earlier than 2005-06-28 | S3 | 944h | 472h | FBI-ISE | Rel-7 |  | Mike | 33.102, 43.020 | Bengt Sahlin, Ericsson | Bengt.Sahlin@ericsson.com |
| 88 | 17.2 | **PacketCable Related aspects** |  | 215d? | 2006-02-01 A | 2006-11-28 | 7% | 200.15d? |  |  |  | 38d |  | S2 | 3984h | 168h | FBI-PCBL |  |  |  |  |  |  |
| 89 | 17.2.1 | Stage 2 of FBI for PacketCable |  | 152d? | 2006-02-01 A | 2006-08-31 | 14% | 131d? |  |  |  | 101d | start no earlier than 2006-02-01 | S2 | 1216h | 168h | FBI-PCBL |  |  |  |  |  |  |
| 90 | 17.2.2 | Protocol impact of FBI for PacketCable |  | 152d? | 2006-05-01 | 2006-11-28 |  |  |  |  |  | 38d | start no earlier than 2006-05-01 | C1 | 1216h |  | FBI-PCBL |  |  |  |  |  |  |
| 91 | 17.3 | **TISPAN Rel 2 related aspects** |  | 218d? | 2006-03-01 | 2006-12-29 |  |  |  |  |  | 15d |  | S2 | 4176h |  | FBI-TISP2 |  |  |  |  |  |  |
| 92 | 17.3.1 | Stage 2 of FBI for TISPAN R2 |  | 152d? | 2006-03-01 | 2006-09-28 |  |  |  |  |  | 81d | start no earlier than 2006-03-01 | S2 | 1216h |  | FBI-TISP2 |  |  |  |  |  |  |
| 93 | 17.3.2 | Protocol impact of FBI for TISPAN R2 |  | 152d? | 2006-06-01 | 2006-12-29 |  |  |  |  |  | 15d | start no earlier than 2006-06-01 | C1 | 1216h |  | FBI-TISP2 |  |  |  |  |  |  |
| 94 | 18 | Access Security Enhancements |  | 195d? | 2005-01-03 A | 2005-09-30 | 30% | 136.5d? | 2005-01-03 | 2005-09-30 | 195d? | 340d | finish no earlier than 2005-09-30 | S3 | 1560h | 468h | ACCSEC2 | Rel-7 | TSG | Michael | 33.102, 43.020 | Bengt Sahlin, Ericsson | Bengt.Sahlin@ericsson.com |
| 95 | 19 | **Mp (MRFC - MRFP) interface** |  | 160d | 2006-02-13 | 2006-09-22 |  |  | 2002-12-13 | 2005-06-01 | 644d | 85d |  | C4 | 3840h |  | Mp | Rel-7 |  |  |  | Emmanuel Gay (Orange) |  |
| 96 | 19.1 | deleted - CT1 aspects of Mp | milestone | 0d | 2006-02-13 | 2006-02-13 |  |  | 2002-12-13 | 2005-06-01 | 644d | 245d | finish no earlier than 2006-02-13 | C1 |  |  | Mp | Rel-7 |  |  | 24.229 | Orange |  |
| 97 | 19.2 | CT3 aspects of Mp |  | 160d | 2006-02-13 | 2006-09-22 |  |  | 2002-12-13 | 2005-06-01 | 644d | 85d | start no earlier than 2006-02-13 | C3 | 1280h |  | Mp | Rel-7 |  |  | 29.162 | Orange |  |
| 98 | 19.3 | CT4 aspects of Mp |  | 160d | 2006-02-13 | 2006-09-22 |  |  | 2002-12-13 | 2005-06-01 | 644d | 85d | finish no earlier than 2006-09-22 | C4 | 1280h |  | Mp | Rel-7 |  |  | 29.333 | Orange |  |
| 99 | 20 | IMS Stage 3 IETF Protocol alignment |  | 261d? | 2004-12-10 A | 2005-12-09 | 40% | 156.6d? | 2004-12-10 | 2005-12-09 | 261d? | 290d | finish no earlier than 2005-12-09 | C1 | 2088h | 835.2h | IMSProtoc | Rel-7 |  |  |  |  |  |
| 100 | 21 | **Support of SMS and MMS over generic 3GPP IP access** |  | 432d? | 2004-10-14 A | 2006-06-09 | 83% | 71.34d? | 2004-10-14 | 2006-06-09 | 432d? | 160d |  | S2 | 6944h | 4088.4h | SMSIP | Rel-7 | TSG | Maurice | TR 23.abc, TS 23.abc | Wenlin Zhang (Huawei) | zhangwenlin@huawei.com |
| 101 | 21.1 | FS on SMSIP |  | 173d? | 2004-10-14 A | 2005-06-13 A | 100% |  | 2004-10-14 | 2005-06-13 | 173d? |  | start no earlier than 2004-10-14 | S2 | 1384h | 1384h | SMSIP | Rel-7 |  |  | 23.804 |  |  |
| 102 | 21.2 | Stage 2 for SMSIP |  | 263d? | 2005-06-08 A | 2006-06-09 | 73% | 72d? | 2005-06-08 | 2006-06-09 | 263d? | 160d | start no earlier than 2005-06-08 | S2 | 2104h | 1528h | SMSIP | Rel-7 |  |  | 23.204 |  |  |
| 103 | 22 | **Evolution of Policy Control and Charging** |  | 556d? | 2004-10-14 A | 2006-11-30 | 39% | 341.78d? | 2004-10-14 | 2006-06-16 | 437d? | 36d |  | S2 | 16408h | 6321.74h | PCC | Rel-7 | TSG | Maurice |  |  |  |
| 104 | 22.1 | TR for PCC |  | 315d? | 2004-10-14 A | 2005-12-29 A | 100% |  | 2004-10-14 | 2005-12-29 | 315d? |  | finish no earlier than 2005-12-28 | S2 | 2520h | 2520h | PCC | Rel-7 |  |  |  |  |  |
| 105 | 22.2 | Stage 2 for PCC |  | 315d? | 2005-07-04 A | 2006-09-15 | 55% | 142d? | 2005-07-04 | 2006-06-16 | 250d? | 90d | finish no earlier than 2006-09-15 | S2 | 2520h | 1384h | PCC | Rel-7 |  |  | 23.203 |  |  |
| 106 | 22.3 | Evolution of policy control and flow based bearer level charging |  | 173d? | 2006-02-01 | 2006-09-29 |  |  | 2005-07-04 | 2006-06-16 | 250d? | 80d | start no earlier than 2006-02-01 | S2 | 1384h |  | PCC | Rel-7 |  |  | 23.207, 23.125, 23.002, 23.228 | Balazs Bertenyi (Nokia) | balazs.bertenyi@nokia.com |
| 107 | 22.4 | Gx reference point for Policy and Charging Control |  | 260d? | 2005-12-02 A | 2006-11-30 | 17% | 216d? |  |  |  | 36d | start no earlier than 2005-12-02 | C3 | 2080h | 352h | PCC | Rel-7 |  | Seung Don | 29.210, 29.207, 29.208 | Thomas Belling (Siemens) | thomas.belling@siemens.com |
| 108 | 22.5 | Rx reference point for PCC CT3 aspects |  | 260d? | 2005-12-02 A | 2006-11-30 | 17% | 216d? |  |  |  | 36d | start no earlier than 2005-12-02 | C3 | 2080h | 352h | PCC | Rel-7 |  | Seung Don | 29.209, 29.211 | Javier Pastor (Ericsson) | j.javier.pastor@ericsson.com |
| 109 | 22.6 | Rx reference point for PCC CT1 aspects |  | 172d? | 2005-12-02 | 2006-09-29 |  |  |  |  |  | 80d | start no earlier than 2005-12-02 | C1 | 1376h |  | PCC | Rel-7 |  |  |  |  |  |
| 110 | 23 | Video Codec Performance Requirements |  | 453d? | 2005-01-03 A | 2006-09-27 | 25% | 339.75d? | 2005-01-03 | 2006-09-27 | 453d? | 82d | finish no earlier than 2006-09-27 | S4 | 3624h | 906h | VICPer | Rel-7 | TSG | Paolo | 26.234, 26.235, 26.346, 26.140 | Juergen Pandel (Siemens AG) | juergen.pandel@siemens.com |
| 111 | 24 | delete at CT#31 - DIAMETER on the GGSN Gi interface |  | 531d? | 2004-09-10 | 2006-09-22 |  |  | 2004-09-10 | 2005-09-16 | 266d? | 85d | finish no earlier than 2006-09-22 | C3 | 4248h |  | DIAMGi | Rel-7 | TSG | Seung Don | 29.061 |  |  |
| 112 | 25 | delete at CT#31 - DIAMETER on the PDG Wi inteface |  | 531d? | 2004-09-10 | 2006-09-22 |  |  | 2004-09-10 | 2005-09-16 | 266d? | 85d | finish no earlier than 2006-09-22 | C3 | 4248h |  | DIAMWi | Rel-7 | TSG | Seung Don | 29.161 |  |  |

Notes:
- 87: Duplicated entry ("ACCSEC2", "Access Security Enhancements", SP-040865) deleted by A.Sultan
- 94: WID approved SA#26. Record created after SA#27. It is about improved GERAN security
- 100: Revised at SP#29
- 106: Approved at SP#29. 23.125 will be discontinued from Release 7.
- 107: Approved at CP#30
- 108: Approved at CP#30
- 111: 13/12/2005 08:00
- 112: 13/12/2005 08:00

| ID | WBS | Task | Type | Duration | Start | Finish | Complete | Remaining | Baseline start | Baseline finish | Baseline duration | Total slack | Constraint | Resources | Work | Actual work | Text1 | Text4 | Text5 | Text6 | Text7 | Text8 |
| --- | --- | --- | --- | --- | --- | --- | --- | --- | --- | --- | --- | --- | --- | --- | --- | --- | --- | --- | --- | --- | --- | --- |
| 113 | 26 | **CAMEL Trunk Triggers** |  | 251d? | 2004-12-17 A | 2005-12-05 A | 100% |  | 2004-12-17 | 2005-12-05 | 251d? |  |  | S1 | 6024h | 6024h | TTCAMEL | Amar Deol, Nortel Networks | deola@nortelnetworks.com | Rel-7 | TSG | Michael |
| 114 | 26.1 | Stage 1 for CAMEL Trunk Triggers |  | 251d? | 2004-12-17 A | 2005-12-05 A | 100% |  | 2004-12-17 | 2005-12-05 | 251d? |  |  | S1 | 2008h | 2008h | TTCAMEL | Amar Deol, Nortel Networks | deola@nortelnetworks.com | Rel-7 | TSG | Michael |
| 115 | 26.2 | CAMEL Trunk Originated Trigger Detection Points |  | 251d? | 2004-12-17 A | 2005-12-05 A | 100% |  | 2004-12-17 | 2005-12-05 | 251d? |  | start no earlier than 2004-12-17 | C4 | 2008h | 2008h | CamelR7 | David Hutton, Nortel Networks | dhutton@nortel.com | Rel-7 | TSG | Kimmo |
| 116 | 27 | MS Antenna Performance Evaluation Method and Requirements |  | 326d? | 2005-01-28 A | 2006-04-28 | 20% | 260.8d? | 2005-01-28 | 2005-11-11 | 206d? | 190d | finish no earlier than 2006-04-28 | G1 | 2608h | 521.6h | APEMR | Ulf.Tegth (TeliaSonera) | Ulf.Tegth@teliasonera.com | Rel-7 | TSG | Paolo |
| 117 | 28 | **Lower 700 MHz Inclusion in the GERAN Specifications** |  | 345d? | 2005-01-03 A | 2006-04-28 | 34% | 226d? | 2005-01-03 | 2006-04-28 | 345d? | 190d |  | GP | 6552h | 1901.6h | GSM710 | Dave Cotton (UTC) | dcotton@mtview.union-tel.com | Rel-7 | TSG | Paolo |
| 118 | 28.1 | Inclusion of the 698 – 746 MHz band into GERAN core specifications |  | 129d? | 2005-01-03 A | 2005-06-30 A | 100% |  | 2005-01-03 | 2005-06-30 | 129d? |  | finish no earlier than 2005-06-30 | G1 | 1032h | 1032h | GSM710-core |  |  | Rel-7 |  | Paolo |
| 119 | 28.2 | G1 aspects of Inclusion of the 698 – 746 MHz band into GERAN test specifications |  | 172.5d? | 2005-08-31 A | 2006-04-28 | 10% | 155.25d? | 2005-08-31 | 2006-04-28 | 172.5d? | 190d | start no earlier than 2005-08-31 | G1 | 1380h | 138h | GSM-710-test |  |  | Rel-7 |  | Stoyan |
| 120 | 28.3 | G3 aspects of Inclusion of the 698 – 746 MHz band into GERAN test specifications |  | 172.5d? | 2005-08-31 A | 2006-04-28 | 10% | 155.25d? |  |  |  | 190d | finish no earlier than 2006-04-28 | G3 | 1380h | 138h | GSM-710-test |  |  | Rel-7 |  | Stoyan |
| 121 | 29 | **Enhancements of VGCS for public authority officials** |  | 436d? | 2004-08-27 A | 2006-04-28 | 82% | 80.44d? | 2004-08-27 | 2005-12-06 | 333d? | 190d |  | S1 | 16600h | 11068.8h | EVGCS | Siemens |  | Rel-7 | TSG | Andrijana |
| 122 | 29.1 | Stage 1 | milestone | 0d? | 2004-08-27 A | 2004-08-27 A | 100% |  | 2004-08-27 | 2004-08-27 | 0d? |  | finish no earlier than 2004-08-27 | S1 |  |  | EVGCS | Joerg Swetina (Siemens AG) | joerg.swetina@SIEMENS.COM | Rel-7 | TSG | Michael |
| 123 | 29.2 | **Architecture and protocol aspects** |  | 401d? | 2004-08-27 A | 2006-03-10 | 93% | 27d? | 2004-08-27 | 2005-12-06 | 333d? | 225d |  | C1 | 9624h | 8976h | EVGCS | Robert Zaus (Siemens) |  | Rel-7 |  |  |
| 124 | 29.2.1 | CT1 aspects of EVGCS |  | 401d? | 2004-08-27 A | 2006-03-10 | 93% | 27d? | 2004-08-27 | 2005-12-06 | 333d? | 225d | finish no earlier than 2006-03-10 | C1 | 3208h | 2992h | EVGCS | Siemens |  | Rel-7 |  |  |
| 125 | 29.2.2 | CT4 aspects of EVGCS |  | 401d? | 2004-08-27 A | 2006-03-10 | 93% | 27d? | 2004-08-27 | 2005-12-06 | 333d? | 225d | finish no earlier than 2006-03-10 | C4 | 3208h | 2992h | EVGCS | Siemens |  | Rel-7 |  |  |
| 126 | 29.3 | GERAN2 aspects |  | 436d? | 2004-08-27 A | 2006-04-28 | 60% | 174.4d? | 2004-08-27 | 2005-11-11 | 316d? | 190d | finish no earlier than 2006-04-28 | G2 | 3488h | 2092.8h | EVGCS | Ken Isaacs (Siemens) | kenneth.isaacs@roke.co.uk | Rel-7 | TSG | Gert |
| 127 | 30 | **Improvements of VGCS for parallel use of services** |  | 381d? | 2005-03-15 A | 2006-08-29 | 33% | 254.21d? | 2005-03-15 | 2005-12-09 | 194d? | 103d |  | S1 | 8830.16h | 1936h | IVGCS |  |  | Rel-7 |  |  |
| 128 | 30.1 | Service Requirements for VGCS improvements |  | 62d? | 2005-03-15 A | 2005-06-08 A | 100% |  | 2005-03-15 | 2005-06-08 | 62d? |  | finish no earlier than 2005-06-08 | S1 | 496h | 496h | IVGCS | Kurt Bischinger (T-Mobile) | kurt.bischinger@t-mobile.at | Rel-7 | TSG | Michael |
| 129 | 30.2 | Stage 2 modifications for VGCS improvements |  | 142d? | 2005-12-01 A | 2006-06-16 | 32% | 97d? | 2005-03-15 | 2005-09-28 | 142d? | 155d | start no earlier than 2005-12-01 | C1 | 1136h | 360h | IVGCS | Kurt Bischinger (T-Mobile) | kurt.bischinger@t-mobile.at | Rel-7 | TSG |  |
| 130 | 30.3 | **Architecture and protocol aspects** |  | 194d? | 2005-12-01 A | 2006-08-29 | 23% | 149d? | 2005-03-15 | 2005-12-09 | 194d? | 103d |  | C1 | 4656h | 1080h | IVGCS | Dieter Jacobsohn (T-Mobile) |  | Rel-7 |  |  |
| 131 | 30.3.1 | CT1 aspects of IVGCS |  | 194d? | 2005-12-01 A | 2006-08-29 | 23% | 149d? | 2005-03-15 | 2005-12-09 | 194d? | 103d | start no earlier than 2005-12-01 | C1 | 1552h | 360h | IVGCS | T-Mobile |  | Rel-7 |  |  |
| 132 | 30.3.2 | CT4 aspects of IVGCS |  | 194d? | 2005-12-01 A | 2006-08-29 | 23% | 149d? | 2005-03-15 | 2005-12-09 | 194d? | 103d | start no earlier than 2005-12-01 | C4 | 1552h | 360h | IVGCS | T-mobile |  | Rel-7 |  |  |
| 133 | 31 | **OSA Rel-7** |  | 394d? | 2005-03-15 A | 2006-09-15 | 13% | 341.15d? | 2005-03-15 | 2005-09-28 | 142d? | 90d |  | S1 | 8752h | 1174.02h | OSA7 | Eamonn Murray (AePONA) | eamonn.murray@aepona.com | Rel-7 | TSG | Michael |
| 134 | 31.1 | Service Requirements for OSA Service Broker |  | 62d? | 2005-03-15 A | 2005-06-08 A | 100% |  | 2005-03-15 | 2005-06-08 | 62d? |  | finish no earlier than 2005-06-08 | S1 | 496h | 496h | OSA7-SB | Eamonn Murray (AePONA) | eamonn.murray@aepona.com | Rel-7 | TSG | Michael |
| 135 | 31.2 | Stage 2 modifications for OSA Service Broker |  | 394d? | 2005-03-15 A | 2006-09-15 | 5% | 374.3d? | 2005-03-15 | 2005-09-28 | 142d? | 90d | finish no earlier than 2006-09-15 | C5 | 3152h | 157.6h | OSA7-SB | Eamonn Murray (AePONA) | eamonn.murray@aepona.com | Rel-7 | TSG | Adrian |
| 136 | 31.3 | New OSA Stage 2/3 enhancements |  | 244d? | 2005-10-11 A | 2006-09-15 | 5% | 231.8d? |  |  |  | 90d | finish no earlier than 2006-09-15 | C5 | 1952h | 97.6h | OSA7 | Damian O’Neill (AePONA) | damian.oneill@aepona.com | Rel-7 |  | Adrian |
| 137 | 32 | Dynamic and interactive multimedia scenes |  | 402d? | 2005-03-15 A | 2006-09-27 | 25% | 301.5d? | 2005-03-15 | 2006-09-27 | 402d? | 82d | finish no earlier than 2006-09-27 | S4 | 3216h | 804h | DIMS | Gaëlle MARTIN-COCHER (Streamezzo) | gaelle.martin-cocher@streamezzo.com | Rel-7 | TSG | Paolo |
| 138 | 33 | Liberty Alliance and 3GPP Security Interworking |  | 147d? | 2005-03-10 A | 2005-09-30 | 20% | 117.6d? | 2005-03-10 | 2005-09-30 | 147d? | 340d | finish no earlier than 2005-09-30 | S3 | 1176h | 235.2h | LibSec | Silke Holtmanns, Nokia | Silke.Holtmanns@NOKIA.COM | Rel-7 | TSG | Maurice |

Notes:
- 115: Not started
- 116: Started / Text3: 25.9xx, 45.005
- 117: Started / Text3: 24.008, 43.022, 44.018, 44.118, 45, 001, 45.005, 51.010, 51.021
- 118: Completed / Text3: 24.008, 43.022, 44.018, 44.118, 45, 001, 45.005,
- 119: Started / Text3: 51.010, 51.021
- 120: Started / Text3: 51.010, 51.021
- 121: Text3: 43.068, 44.068, 24.008, 29.002
- 122: Text3: 42.068, 43.068
- 123: Text3: 43.068, 44.068
- 124: Text3: 43.068, 44.068, 24.008
- 125: Text3: 29.002
- 128: "completeed" as from Chris S' e-mail / Text3: 42.068
- 129: Text3: 43.068
- 130: Text3: 44.068
- 131: Text3: 43.068, 44.068, 24.008
- 132: Text3: 29.002
- 134: az: WID URL corrected / Text3: 22.127
- 135: Completion => 09/2006 / Text3: 23.198
- 136: CT#30: WID approved. / Text3: 23.198, 29.198,29.998,29.199
- 137: Started / Text3: 26.234, 23.346, 26.140, 26.244
- 138: WID approved SA#27. / Text3: 33.980

| ID | WBS | Task | Type | Duration | Start | Finish | Complete | Remaining | Baseline start | Baseline finish | Baseline duration | Total slack | Constraint | Resources | Work | Actual work | Text4 | Text5 | Text6 | Text7 | Text8 | Text1 | Text10 |
| --- | --- | --- | --- | --- | --- | --- | --- | --- | --- | --- | --- | --- | --- | --- | --- | --- | --- | --- | --- | --- | --- | --- | --- |
| 139 | 34 | **WLAN-UMTS Interworking Phase 2** |  | 371d? | 2004-01-05 A | 2005-06-07 | 99% | 0d? | 2004-01-05 | 2005-06-07 | 371d? | 424d |  | S1 | 3888h | 3888h | Fredric Paint, Telenor | frederic.paint@telenor.com | Rel-7 | TSG | Michael |  |  |
| 140 | 34.1 | Stage 1 on Session Continuity |  | 115d? | 2004-01-05 A | 2004-06-11 A | 100% |  | 2004-01-05 | 2004-06-11 | 115d? |  | start no earlier than 2004-01-05 | S1 | 920h | 920h |  |  | Rel-7 |  |  | WLAN-SC | SP-24 |
| 141 | 34.2 | Stage 2 on Session Continuity: covered by SAE | milestone | 0d? | 2005-06-07 | 2005-06-07 |  |  | 2005-06-07 | 2005-06-07 | 0d? | 424d | finish no earlier than 2005-06-07 | S2 |  |  |  |  | Rel-7 |  |  |  |  |
| 142 | 35 | **Voice call continuity between CS and IMS (incl. I-WLAN)** |  | 479d? | 2004-12-31 A | 2006-11-01 | 36% | 305.52d? | 2004-12-31 | 2006-06-23 | 386d? | 57d |  | S2 | 15296h | 4354.4h | Andy Bennett, Lucent; Roger Bunting, Cingular | andybennett@lucent.com | Rel-7 |  | Maurice | VCC |  |
| 143 | 35.1 | TR for VCC |  | 245d? | 2004-12-31 A | 2005-12-08 A | 100% |  | 2004-12-31 | 2005-12-08 | 245d? |  | finish no earlier than 2005-12-08 | S2 | 1960h | 1960h |  |  | Rel-7 |  |  | VCC |  |
| 144 | 35.2 | Stage 1 for VCC |  | 140d? | 2005-03-17 A | 2005-09-28 A | 100% |  | 2005-03-17 | 2005-09-28 | 140d? |  | finish no earlier than 2005-09-28 | S1 | 1120h | 1120h |  |  | Rel-7 |  | Mike | VCC |  |
| 145 | 35.3 | Stage 2 for VCC |  | 264d? | 2005-09-06 A | 2006-09-08 | 24% | 201d? | 2005-09-06 | 2006-06-09 | 199d? | 95d | finish no earlier than 2006-09-08 | S2 | 2112h | 504h |  |  | Rel-7 |  |  | VCC |  |
| 146 | 35.4 | **Stage 3 for VCC** |  | 196d? | 2006-02-01 | 2006-11-01 |  |  | 2005-09-23 | 2006-06-23 | 196d? | 57d |  | C1 | 6272h |  |  |  | Rel-7 |  |  | VCC |  |
| 147 | 35.4.1 | CT1 aspects of VCC |  | 196d? | 2006-02-01 | 2006-11-01 |  |  | 2005-09-23 | 2006-06-23 | 196d? | 57d | start no earlier than 2006-02-01 | C1 | 1568h |  | Lucent |  | Rel-7 |  |  | VCC |  |
| 148 | 35.4.2 | CT3 aspects of VCC |  | 196d? | 2006-02-01 | 2006-11-01 |  |  | 2005-09-23 | 2006-06-23 | 196d? | 57d | start no earlier than 2006-02-01 | C3 | 1568h |  | Lucent |  | Rel-7 |  |  | VCC |  |
| 149 | 35.4.3 | CT4 aspects of VCC |  | 196d? | 2006-02-01 | 2006-11-01 |  |  | 2005-09-23 | 2006-06-23 | 196d? | 57d | start no earlier than 2006-02-01 | C4 | 1568h |  | Lucent |  | Rel-7 |  |  | VCC |  |
| 150 | 36 | **OAM&P** |  | 740d? | 2004-02-16 A | 2006-12-15 | 20% | 590.17d? | 2004-02-16 | 2007-03-30 | 815d? | 25d |  | S5 | 102049h | 21510.5h | Christian TOCHE | toche@nortel.com | Rel-7 | TSG | Adrian | OAM7 |  |
| 151 | 36.1 | **Network Infrastructure Management** |  | 336d? | 2005-09-02 A | 2006-12-15 | 17% | 278.23d? | 2005-09-02 | 2006-12-22 | 341d? | 25d |  | S5 | 54592h | 8924.16h | Christian TOCHE | toche@nortel.com | Rel-7 |  |  | OAM7-NIM |  |
| 152 | 36.1.1 | Enhance NRM to accommodate NGN (IMS as basis of the Next Generation Network) |  | 336d? | 2005-09-02 | 2006-12-15 |  |  | 2005-09-02 | 2006-12-22 | 341d? | 25d | finish no earlier than 2006-12-15 | S5 | 2688h |  | BT |  | Rel-7 |  |  | OAM7-NIM-NGN |  |
| 153 | 36.1.2 | IRP usage scenarios |  | 336d? | 2005-09-02 A | 2006-12-15 | 1% | 332.64d? | 2005-09-02 | 2005-12-07 | 69d? | 25d | finish no earlier than 2006-12-15 | S5 | 2688h | 26.88h | Lucent |  | Rel-7 |  |  | OAM7-NIM |  |
| 154 | 36.1.3 | Co-operative Element Management interface (CO-OP) |  | 336d? | 2005-09-02 A | 2006-12-15 | 65% | 117.6d? | 2005-09-02 | 2006-03-31 | 151d? | 25d | finish no earlier than 2006-12-15 | S5 | 2688h | 1747.2h | Motorola |  | Rel-7 |  |  | OAM7-NIM-COOP |  |
| 155 | 36.1.4 | Network Management (NM) Itf-N performance criteria |  | 336d? | 2005-09-02 A | 2006-12-15 | 10% | 302.4d? | 2005-09-02 | 2005-12-07 | 69d? | 25d | finish no earlier than 2006-12-15 | S5 | 2688h | 268.8h | China Mobile |  | Rel-7 |  |  | OAM7-NIM |  |
| 156 | 36.1.5 | Delta synchronization between IRP Manager and IRP Agent |  | 336d? | 2005-09-02 A | 2006-12-15 | 45% | 184.8d? | 2005-09-02 | 2005-12-07 | 69d? | 25d | finish no earlier than 2006-12-15 | S5 | 2688h | 1209.6h | Siemens |  | Rel-7 |  |  | OAM7-NIM |  |
| 157 | 36.1.6 | Subscription Management (SuM) IRP Solution Sets |  | 336d? | 2005-09-02 A | 2006-12-15 | 45% | 184.8d? | 2005-09-02 | 2006-03-31 | 151d? | 25d | finish no earlier than 2006-12-15 | S5 | 2688h | 1209.6h | T-Mobile |  | Rel-7 |  |  | OAM7-NIM-SuM |  |
| 158 | 36.1.7 | Integration Reference Point (IRP) Security Management |  | 336d? | 2005-09-02 A | 2006-12-15 | 15% | 285.6d? | 2005-09-02 | 2006-06-30 | 216d? | 25d | finish no earlier than 2006-12-15 | S5 | 2688h | 403.2h | Huawei |  | Rel-7 |  |  | OAM7-NIM |  |
| 159 | 36.1.8 | Integration Reference Point (IRP) Methodology |  | 336d? | 2005-09-02 A | 2006-12-15 | 10% | 302.4d? | 2005-09-02 | 2006-12-07 | 330d? | 25d | finish no earlier than 2006-12-15 | S5 | 2688h | 268.8h | Ericsson |  | Rel-7 |  |  | OAM7-NIM |  |
| 160 | 36.1.9 | Partial suspension of Itf-N during maintenance/testing |  | 336d? | 2005-09-02 A | 2006-12-15 | 20% | 268.8d? | 2005-09-02 | 2005-12-07 | 69d? | 25d | finish no earlier than 2006-12-15 | S5 | 2688h | 537.6h | Siemens |  | Rel-7 |  |  | OAM7-NIM |  |
| 161 | 36.1.10 | Advanced Alarming on Itf-N |  | 336d? | 2005-09-02 A | 2006-12-15 | 35% | 218.4d? | 2005-09-02 | 2006-06-30 | 216d? | 25d | finish no earlier than 2006-12-15 | S5 | 2688h | 940.8h | Siemens |  | Rel-7 |  |  | OAM7-NIM |  |
| 162 | 36.1.11 | Management of Legacy Equipment |  | 336d? | 2005-09-02 | 2006-12-15 |  |  | 2005-09-02 | 2005-12-07 | 69d? | 25d | finish no earlier than 2006-12-15 | S5 | 2688h |  | Siemens |  | Rel-7 |  |  | OAM7-NIM |  |
| 163 | 36.1.12 | Rules for Vendor Specific Extensions |  | 336d? | 2005-09-02 A | 2006-12-15 | 10% | 302.4d? | 2005-09-02 | 2006-03-31 | 151d? | 25d | finish no earlier than 2006-12-15 | S5 | 2688h | 268.8h | Siemens |  | Rel-7 |  |  | OAM7-NIM |  |
| 164 | 36.1.13 | CN CS Bearer Transport Network (BTN) relative NRM |  | 336d? | 2005-09-02 A | 2006-12-15 | 40% | 201.6d? | 2005-09-02 | 2005-12-07 | 69d? | 25d | finish no earlier than 2006-12-15 | S5 | 2688h | 1075.2h | China Mobile |  | Rel-7 |  |  | OAM7-NIM |  |
| 165 | 36.1.14 | Backward and Forward Compatibility of IRP systems |  | 336d? | 2005-09-02 A | 2006-12-15 | 5% | 319.2d? | 2005-09-02 | 2006-12-22 | 341d? | 25d | finish no earlier than 2006-12-15 | S5 | 2688h | 134.4h | Ericsson |  | Rel-7 |  |  | OAM7-NIM-BFC |  |
| 166 | 36.1.15 | Study of Element Operations Systems Function (EOSF) definition |  | 336d? | 2005-09-02 A | 2006-12-15 | 5% | 319.2d? | 2005-09-02 | 2006-12-22 | 341d? | 25d | finish no earlier than 2006-12-15 | S5 | 2688h | 134.4h | China Mobile |  | Rel-7 |  |  | OAM7-NIM- EOSF |  |
| 167 | 36.1.16 | Study of SOAP/HTTP IRP Solution Sets |  | 336d? | 2005-09-02 A | 2006-12-15 | 1% | 332.64d? | 2005-09-02 | 2006-09-22 | 276d? | 25d | finish no earlier than 2006-12-15 | S5 | 2688h | 26.88h | Nortel |  | Rel-7 |  |  | OAM7-NIM-SOAP |  |
| 168 | 36.1.17 | Study of Itf-N Implementation Conformance Statement (ICS) template |  | 336d? | 2005-09-02 A | 2006-12-15 | 10% | 302.4d? | 2005-09-02 | 2006-09-22 | 276d? | 25d | finish no earlier than 2006-12-15 | S5 | 2688h | 268.8h | China Mobile |  | Rel-7 |  |  | OAM7-NIM-ICS |  |
| 169 | 36.1.18 | Study of IRP Information Model |  | 336d? | 2005-09-02 A | 2006-12-15 | 15% | 285.6d? | 2005-09-02 | 2006-09-22 | 276d? | 25d | finish no earlier than 2006-12-15 | S5 | 2688h | 403.2h | Motorola |  | Rel-7 |  |  | OAM7-NIM-IM |  |
| 170 | 36.1.19 | NEW Repeater Network Ressource Model (NRM) definition |  | 220d? | 2006-02-13 | 2006-12-15 |  |  |  |  |  | 25d | start no earlier than 2006-02-13 | S5 | 1760h |  | China Mobile |  | Rel-7 |  |  | OAM7-NIM |  |
| 171 | 36.1.20 | NEW UTRAN radio channel power monitoring |  | 220d? | 2006-02-13 | 2006-12-15 |  |  |  |  |  | 25d | start no earlier than 2006-02-13 | S5 | 1760h |  | China Mobile |  | Rel-7 |  |  | OAM7-NIM |  |

Notes:
- 139: Created at TSG#27 by A. Sultan because of WLAN items belonging to Rel-7
- 142: WID approved SA#27. Revised at SA#28. / Text3: 22.101, 22.228, 23.228
- 143: Text3: 23.806
- 145: Text3: 23.206
- 146: Text3: new TS, 24.229, 23.008, 23.009, 23.078, 29.078, 29.163, 29.228, 29.229, 29.230, 29.278, 29.328, 29.329
- 147: Text3: new TS, 24.229
- 148: Text3: 29.163
- 149: Text3: 23.008, 23.009, 23.078, 29.078, 29.228, 29.229, 29.230, 29.278, 29.328, 29.329
- 150: Created at TSG#27 by A. Sultan due to the split of the OAM BB Trace Rel-6/Rel-7 / Text3: see WT WIDs
- 151: SA#28 (06/2005) created / Text3: see WT WIDs
- 152: SA#28 (06/2005) created / Text3: 32.632, 32.633, 32.634, 32.635
- 153: SA#28 (06/2005) created. 09/05 Changed title to Study / Text3: new TR 32.8xy
- 154: SA#28 (06/2005) created. 09/05 Changed title to Study / Text3: new TR 32.8xy, 32.101
- 155: SA#28 (06/2005) created. 09/05 Changed title to Study / Text3: new TS 32.yzx
- 156: SA#28 (06/2005) created. 09/05 Changed title to Study / Text3: new TR 32.8xy,new TSs 32.111-n,32.60n; For n = 1 to 5
- 157: SA#28 (06/2005) created / Text3: 32.101,32.175, new TSs 32.161,32.307,32.317,32.607,32.617,32.667
- 158: SA#28 (06/2005) created / Text3: New TSs 32.372,32.373,32.374; 32.111,32.30x,32.32x,32.33x,32.34x,32.35x,32.36x,32.41x,32.60x,32.61x,32.66x
- 159: SA#28 (06/2005) created / Text3: New TSs 32.15w,32.15x,32.15y,32.15z; 32.150,32.151,32.152
- 160: SA#28 (06/2005) created. 09/05 Changed title to Study / Text3: new TR 32.8xy, new TSs 32.30n,32.60n,32.61n; For n = 1 to 5
- 161: SA#28 (06/2005) created. 09/05 Changed title to Study / Text3: new TR 32.8xy ; New TSs 32.111-n,32.30n; For n = 1 to 5
- 162: SA#28 (06/2005) created. 09/05 Changed title to Study / Text3: new TS 32.xxx, New TSs 32.62n,32.63n,32.64n,32.65n,32.71n,32.74n,32.69n; For n = 1 to 5
- 163: SA#28 (06/2005) created / Text3: 32.62n; For n = 1 to 5
- 164: SA#28 (06/2005) created / Text3: New Tss TS 32.xx1,TS 32.xx2,TS 32.xx3,TS 32.xx4
- 165: SA#29 (09/2005) created / Text3: TR 32.805. new TS 32.15X
- 166: SA#29 (09/2005) created / Text3: new TR 32.8xy
- 167: SA#29 (09/2005) created / Text3: new TR 32.8xy
- 168: SA#29 (09/2005) created / Text3: new TR 32.8xy
- 169: SA#29 (09/2005) created / Text3: new TR 32.8xy
- 170: SA#30 (12/2005) created / Text3: 32.64n; For n = 1 to 5
- 171: SA#30 (12/2005) created / Text3: 32.403, 32.64n; For n = 1 to 5

| ID | WBS | Task | Duration | Start | Finish | Complete | Remaining | Baseline start | Baseline finish | Baseline duration | Total slack | Constraint | Resources | Work | Actual work | Text1 | Text4 | Text5 | Text6 | Text7 | Text8 |
| --- | --- | --- | --- | --- | --- | --- | --- | --- | --- | --- | --- | --- | --- | --- | --- | --- | --- | --- | --- | --- | --- |
| 172 | 36.2 | **Performance Management** | 336d? | 2005-09-02 A | 2006-12-15 | 28% | 242.09d? | 2005-09-02 | 2006-12-29 | 346d? | 25d |  | S5 | 20576h | 4999.68h | OAM7-PM | Christian TOCHE | toche@nortel.com | Rel-7 |  |  |
| 173 | 36.2.1 | Performance measurements definition for CN CS | 336d? | 2005-09-02 A | 2006-12-15 | 60% | 134.4d? | 2005-09-02 | 2006-03-31 | 151d? | 25d | finish no earlier than 2006-12-15 | S5 | 2688h | 1612.8h | OAM7-PM | China Mobile |  | Rel-7 |  |  |
| 174 | 36.2.2 | Enhancement UTRAN performance measurements definition | 336d? | 2005-09-02 A | 2006-12-15 | 15% | 285.6d? | 2005-09-02 | 2005-12-07 | 69d? | 25d | finish no earlier than 2006-12-15 | S5 | 2688h | 403.2h | OAM7-PM | China Mobile |  | Rel-7 |  |  |
| 175 | 36.2.3 | Add TDD specific counters in Performance measurement | 336d? | 2005-09-02 A | 2006-12-15 | 75% | 84d? | 2005-09-02 | 2006-12-29 | 346d? | 25d | finish no earlier than 2006-12-15 | S5 | 2688h | 2016h | OAM7-PM | CATT |  | Rel-7 |  |  |
| 176 | 36.2.4 | ATM bearer network Performance measurements | 336d? | 2005-09-02 A | 2006-12-15 | 20% | 268.8d? | 2005-09-02 | 2005-12-07 | 69d? | 25d | finish no earlier than 2006-12-15 | S5 | 2688h | 537.6h | OAM7-PM | ZTE |  | Rel-7 |  |  |
| 177 | 36.2.5 | IP bearer network Performance measurement definitions | 336d? | 2005-09-02 A | 2006-12-15 | 15% | 285.6d? | 2005-09-02 | 2005-12-07 | 69d? | 25d | finish no earlier than 2006-12-15 | S5 | 2688h | 403.2h | OAM7-PM | China Mobile |  | Rel-7 |  |  |
| 178 | 36.2.6 | Performance measurements definition for IMS | 336d? | 2005-09-02 A | 2006-12-15 | 1% | 332.64d? | 2005-09-02 | 2006-12-22 | 341d? | 25d | finish no earlier than 2006-12-15 | S5 | 2688h | 26.88h | OAM7-PM-IMS | China Mobile |  | Rel-7 |  |  |
| 179 | 36.2.7 | NEW HSDPA performance measurements | 220d? | 2006-02-13 | 2006-12-15 |  |  |  |  |  | 25d | start no earlier than 2006-02-13 | S5 | 1760h |  | OAM7-PM | China Mobile |  | Rel-7 |  |  |
| 180 | 44.5 | **Trace Management** | 740d? | 2004-02-16 A | 2006-12-15 | 21% | 580.91d? | 2004-02-16 | 2007-03-30 | 815d? | 25d |  | S5 | 20961.1h | 3794.64h | OAM7-Trace | Christian TOCHE | toche@nortel.com | Rel-7 | TSG |  |
| 181 | 36.3.1 | Trace Management for IMS | 420d? | 2005-05-09 | 2006-12-15 |  |  | 2005-05-09 | 2005-12-08 | 154d? | 25d | finish no earlier than 2006-12-15 | S5 | 3360h |  | OAM7-Trace-IMS | Nortel |  | Rel-7 | TSG |  |
| 182 | 36.3.2 | SIP enhancements for trace | 603.14d? | 2004-02-16 A | 2006-06-16 | 2% | 591.08d? | 2004-02-16 | 2006-06-16 | 603.14d? | 155d | finish no earlier than 2006-06-16 | C1 | 4825.12h | 96.5h | OAM7-Trace-SIP |  |  | Rel-7 |  |  |
| 183 | 36.3.3 | End-to-end Service Level tracing for IMS | 286d? | 2005-11-11 A | 2006-12-15 | 35% | 185.9d? | 2005-11-11 | 2006-06-30 | 166d? | 25d | finish no earlier than 2006-12-15 | S5 | 2288h | 800.8h | OAM7-Trace-IMS | Vodafone |  | Rel-7 | TSG |  |
| 184 | 36.3.4 | IRP for Subscriber and Equipment Trace Management | 336d? | 2005-09-02 A | 2006-12-15 | 5% | 319.2d? | 2005-09-02 | 2007-03-30 | 411d? | 25d | finish no earlier than 2006-12-15 | S5 | 2688h | 134.4h | OAM7-Trace-IRP | Nortel |  | Rel-7 | TSG |  |
| 185 | 36.3.5 | Trace record content for UTRAN TDD | 420d? | 2005-05-09 A | 2006-12-15 | 75% | 105d? | 2005-05-09 | 2005-12-08 | 154d? | 25d | finish no earlier than 2006-12-15 | S5 | 3360h | 2520h | OAM7-Trace-TDD | CATT |  | Rel-7 | TSG |  |
| 186 | 37 | Trust Requirements for Open Platforms in 3GPP | 115d? | 2005-01-03 A | 2005-06-10 | 10% | 103.5d? | 2005-01-03 | 2005-06-10 | 115d? | 420d | finish no earlier than 2005-06-10 | S3 | 920h | 92h | TrustOP | Selim Aissi, Sundeep Bajikar, Intel Corporation |  | Rel-7 | TSG | Michael |
| 187 | 38 | Development of UEA2 and UIA2 | 268d? | 2004-12-01 A | 2005-12-09 | 65% | 93.8d? | 2004-12-01 | 2005-12-09 | 268d? | 290d | finish no earlier than 2005-12-09 | S3 | 2144h | 1393.6h | AlgUEA2 | Per Christoffersson, Teliasonera | per.christoffersson@teliasonera.com | Rel-7 | TSG | Michael |
| 188 | 39 | Lawful Interception in the 3GPP Rel-7 architecture | 118d? | 2005-06-28 A | 2005-12-08 | 40% | 70.8d? | 2005-06-28 | 2005-12-08 | 118d? | 291d | start no earlier than 2005-06-28 | S3 | 944h | 377.6h | LI-7A | Berthold Wilhelm, BMWI | berthold.wilhelm@regtp.de | Rel-7 |  | Mike |
| 189 | 40 | **Support of Conversational Services in A/Gb mode via the PS domain** | 276d? | 2005-04-08 A | 2006-04-28 |  | 276d? | 2005-04-08 | 2006-04-28 | 276d? | 190d |  | GP | 8611.2h | 198.72h | SCSAGB | Gunnar Hedby, Ericsson | gunnar.hedby@ericsson.com | Rel-7 |  | Paolo |
| 190 | 40.1 | Definition of radio resource management functionality | 276d? | 2005-04-08 | 2006-04-28 |  |  | 2005-04-08 | 2006-04-28 | 276d? | 190d | finish no earlier than 2006-04-28 | G1 | 2208h |  | SCSAGB-RRM | Gunnar Hedby, Ericsson | gunnar.hedby@ericsson.com | Rel-7 |  | Paolo |
| 191 | 40.2 | Radio Channel Support | 276d? | 2005-04-08 | 2006-04-28 |  |  | 2005-04-08 | 2006-04-28 | 276d? | 190d | finish no earlier than 2006-04-28 | G2 | 2208h |  | SCSAGB-RCHS | Gunnar Hedby, Ericsson | gunnar.hedby@ericsson.com | Rel-7 |  | Gert |
| 192 | 40.3 | Modifications to FLO | 276d? | 2005-04-08 | 2006-04-28 |  |  | 2005-04-08 | 2006-04-28 | 276d? | 190d | finish no earlier than 2006-04-28 | G2 | 2208h |  | SCSAGB-FLO | Gunnar Hedby, Ericsson | gunnar.hedby@ericsson.com | Rel-7 |  | Gert |
| 193 | 41 | **Addition of new frequency band to GSM (T-GSM810)** | 206d? | 2005-04-08 A | 2006-01-20 | 56% | 90.68d? | 2005-04-08 | 2005-11-18 | 161d? | 260d |  | GP | 5392h | 2096h | TGSM810 | Chen De, Huawei | chende@huawei.com | Rel-7 |  | Paolo |
| 194 | 41.1 | Changes to core specification | 106d? | 2005-04-08 A | 2005-09-02 A | 100% |  | 2005-04-08 | 2005-09-02 | 106d? |  | finish no earlier than 2005-09-02 | GP | 848h | 848h | TGSM810-Core | Chen De, Huawei | chende@huawei.com | Rel-7 |  | Paolo |
| 195 | 41.2 | Changes to MS testing specification | 206d? | 2005-04-08 | 2006-01-20 |  |  | 2005-04-08 | 2005-11-18 | 161d? | 260d | finish no earlier than 2006-01-20 | G3 | 1648h |  | TGSM810-Mstest | Chen De, Huawei | chende@huawei.com | Rel-7 |  | Stoyan |
| 196 | 41.3 | Changes to BTS testing specification | 156d? | 2005-04-08 A | 2005-11-11 A | 100% |  | 2005-04-08 | 2005-09-02 | 106d? |  | finish no earlier than 2005-11-11 | G1 | 1248h | 1248h | TGSM810-BTStest | Chen De, Huawei | chende@huawei.com | Rel-7 |  | Paolo |

Notes:
- 172: SA#28 (06/2005) created / Text3: see WT WIDs
- 173: Text3: New TS 32.xyz
- 174: Text3: 32.403
- 175: SA#28 (06/2005) created / Text3: 32.403
- 176: SA#28 (06/2005) created / Text3: 32.403
- 177: SA#28 (06/2005) created / Text3: 32.403
- 178: SA#29 (09/2005) created / Text3: new TS 32.xyz
- 179: SA#30 (12/2005) created / Text3: 32.403
- 180: TSG#27: SA5 BB WID to add Trace for IMS (SIP) CN1 24.229 has IETF dependency / Text3: see WT WIDs
- 181: Text3: 32.421,32.422,32.423
- 183: 07/2005: OMA (Stage 1), Stage 2/3 SA5, CT1/3/4 / Text3: 32.101,32.421,32.422,32.423
- 184: SA#29 (09/2005) created / Text3: 32.421,32.422,32.423. 3 new TS 32.4x1,2,3
- 185: Text3: 32.421,32.422,32.423
- 186: WID approved SA#26. Record created after SA#27
- 187: WID approved SA#26, Dependant on Funding Availability. Record created after SA#27 / Text3: 33.102
- 189: Originally started Nov. 2003 as GP-030443
- 193: Text3: 45.005, 45.050, 24.008, 45.008, 45.001, 43.022, 43.030, 44.018, 44.060, 51.010-1, 51.021
- 194: Text3: 45.005, 45.050, 24.008, 45.008, 45.001, 43.022, 43.030, 44.018, 44.060
- 195: Not started / Text3: 51010-1
- 196: Text3: 51021

| ID | WBS | Task | Duration | Start | Finish | Complete | Remaining | Baseline start | Baseline finish | Baseline duration | Total slack | Constraint | Resources | Work | Actual work | Text1 | Text4 | Text5 | Text6 | Text8 | Text3 | Text7 |
| --- | --- | --- | --- | --- | --- | --- | --- | --- | --- | --- | --- | --- | --- | --- | --- | --- | --- | --- | --- | --- | --- | --- |
| 197 | 42 | **Handover of dedicated and shared resources while in dual transfer mode** | 276d? | 2005-04-08 A | 2006-04-28 | 10% | 248.4d? | 2005-04-08 | 2006-11-17 | 421d? | 190d |  | GP | 8832h | 662.4h | HODSRDTM | Rami Vaittinen, Nokia | rami.vaittinen@nokia.com | Rel-7 | Paolo |  |  |
| 198 | 42.1 | Handover of dedicated and shared resources while in dual transfer mode | 276d? | 2005-04-08 A | 2006-04-28 | 30% | 193.2d? | 2005-04-08 | 2006-04-28 | 276d? | 190d | finish no earlier than 2006-04-28 | G2 | 2208h | 662.4h | HODSRDTM-G2 | Rami Vaittinen, Nokia | rami.vaittinen@nokia.com | Rel-7 | Gert | 43.055, 44.018, 44.060 |  |
| 199 | 42.2 | MS Conformance Testing | 276d? | 2005-04-08 | 2006-04-28 |  |  |  |  |  | 190d | start no earlier than 2005-04-08 | G3 | 2208h |  | HODSRDTM-Mstest | Rami Vaittinen, Nokia | rami.vaittinen@nokia.com | Rel-7 | Stoyan | 51-010 |  |
| 200 | 42.3 | BTS conformance testing | 276d? | 2005-04-08 | 2006-04-28 |  |  | 2005-04-08 | 2006-11-17 | 421d? | 190d | finish no earlier than 2006-04-28 | G1 | 2208h |  | HODSRDTM-BTStest | Rami Vaittinen, Nokia | rami.vaittinen@nokia.com | Rel-7 | Paolo | 51.026 |  |
| 201 | 43 | Future GERAN Evolution | 206d? | 2005-04-08 A | 2006-01-20 | 75% | 51.5d? | 2005-04-08 | 2005-11-11 | 156d? | 260d | finish no earlier than 2006-01-20 | GP | 1648h | 1236h | FGE | Eddie Riddington, Nokia Corporation | eddie.riddington@nokia.com | Rel-7 | Paolo |  |  |
| 202 | 44 | 3G-324M Video Telephony Call Setup Times Improvements | 341d? | 2005-06-08 A | 2006-09-27 | 50% | 170.5d? | 2005-06-08 | 2006-09-27 | 341d? | 82d | finish no earlier than 2006-09-27 | S4 | 2728h | 1364h | VTCSTI | Edward Hall (Vodafone) | edward.hall@vodafone.co.uk | Rel-7 | Paolo | 26.abc |  |
| 203 | 45 | **Identification of Communication Services in IMS** | 283d? | 2005-05-02 A | 2006-05-31 | 77% | 63.98d? | 2005-05-02 | 2006-09-08 | 355d? | 167d |  | S2 | 5272h | 2456h | ServID | Stephen Terrill, Ericsson | stephen.terrill@ericsson.com | Rel-7 | Maurice | 23.228, 23.218, 23.125 |  |
| 204 | 45.1 | TR for ICS | 232d? | 2005-05-02 A | 2006-03-21 A | 100% |  | 2005-05-02 | 2006-03-21 | 232d? |  | finish no earlier than 2006-03-20 | S2 | 1856h | 1856h | ServID |  |  | Rel-7 |  | 23.816 |  |
| 205 | 45.2 | Stage 2 for ICS | 144d? | 2005-11-11 A | 2006-05-31 | 41% | 85d? | 2006-03-27 | 2006-09-08 | 120d? | 167d | start no earlier than 2005-11-11 | S2 | 1152h | 472h | ServID |  |  | Rel-7 |  |  |  |
| 206 | 46 | **VoIMS bearer related enhancements** | 354d? | 2005-03-15 A | 2006-07-21 | 60% | 142.42d? | 2005-03-15 | 2006-07-21 | 354d? | 130d |  | S2 | 6863.2h | 2472h | VoIMS |  |  | Rel-7 |  |  |  |
| 207 | 46.1 | FS on enhancement of radio performance for VoIMS | 320d? | 2005-05-02 A | 2006-07-21 | 35% | 208d? | 2005-05-02 | 2006-07-21 | 320d? | 130d | finish no earlier than 2006-07-21 | S2 | 2560h | 896h | VoIMS | Laurence Lautier, Nortel Networks | lautierl@nortel.com | Rel-7 | Maurice | 23.807 |  |
| 208 | 46.2 | Improved support of IMS Realtime Services using HSDPA/HSUPA | 197d? | 2005-03-15 A | 2005-12-14 A | 100% |  | 2005-03-15 | 2005-12-14 | 197d? |  | start no earlier than 2005-03-15 | R2 | 1576h | 1576h | RANimp-IMSRealTime | Don Zelmer | don.zelmer@CINGULAR.COM | Rel-7 | MCC_RAN |  | TSG |
| 209 | 47 | Performance Characterization of VoIMS over HSDPA\EUL channels | 402d? | 2005-03-15 A | 2006-09-27 | 10% | 361.8d? | 2005-03-15 | 2006-03-15 | 262d? | 82d | finish no earlier than 2006-09-27 | S4 | 3216h | 321.6h | VoIMS-PCVoIMS | Dimitris Vasilaras (Lucent Technologies) | dvasilaras@lucent.com | Rel-7 | Paolo | 26.935 | TSG |
| 210 | 48 | **Optimizations for Multimedia Telephony over IMS** | 261d? | 2005-09-28 A | 2006-09-27 | 5% | 247.95d? | 2005-09-28 | 2006-09-27 | 261d? | 82d |  | S4 | 4176h | 208.8h | OMTIMS | Olle Franceschi (Ericsson) | olle.franceschi@ericsson.com | Rel-7 | Paolo | 26.235, 26.236 |  |
| 211 | 48.1 | Characterisation of Adaptive Jitter Management Performance for VoIP Services | 261d? | 2005-09-28 A | 2006-09-27 | 5% | 247.95d? | 2005-09-28 | 2006-09-27 | 261d? | 82d | finish no earlier than 2006-09-27 | S4 | 2088h | 104.4h | OMTIMS-CAJMP | David Huo (Lucent Technologies) | dhuo@lucent.com | Rel-7 | Paolo |  |  |
| 212 | 49 | End-to-End Multimedia Services Performance Metrics | 261d? | 2005-09-28 | 2006-09-27 |  |  | 2005-09-28 | 2006-09-27 | 261d? | 82d | finish no earlier than 2006-09-27 | S4 | 2088h |  | E2EMSPM | Zhang Yan (China Mobile) | zhangyanyf@chinamobile.com | Rel-7 | Paolo |  |  |
| 213 | 50 | **WLAN Interworking – Private Network access from WLAN 3GPP IP Access** | 252d? | 2005-10-10 A | 2006-09-26 | 15% | 214.65d? | 2005-10-10 | 2006-10-20 | 270d? | 83d |  | S2 | 6920h | 824h | WLANPNA |  |  | Rel-7 | Maurice |  |  |
| 214 | 50.1 | WLAN-PNA - Stage 2 | 185d? | 2005-10-10 A | 2006-06-23 | 56% | 82d? |  |  |  | 150d | start no earlier than 2005-10-10 | S2 | 1480h | 824h | WLANPNA-st2 | Toshiyuki Tamura (NEC) | tamurato@aj.jp.nec.com | Rel-7 | Maurice | 23.234, 33.234 |  |
| 215 | 50.2 | **WLAN-PNA - Stage 3** | 170d? | 2006-02-01 | 2006-09-26 |  |  | 2005-10-10 | 2006-10-20 | 206.31d? | 83d |  | C1 | 5440h |  | WLANPNA-St3 | Pierre-Jean Muller (NEC) | pierre-jean.muller@nectech.fr | Rel-7 | Andrijana |  | TSG |
| 216 | 50.2.1 | CT1 aspets for WLAN-PNA | 170d? | 2006-02-01 | 2006-09-26 |  |  |  |  |  | 83d | start no earlier than 2006-02-01 | C1 | 1360h |  | WLANPNA-st3-CT1 | Pierre-Jean Muller (NEC) | pierre-jean.muller@nectech.fr | Rel-7 | Andrijana | 24.234 |  |
| 217 | 50.2.2 | CT3 aspets for WLAN-PNA | 170d? | 2006-02-01 | 2006-09-26 |  |  |  |  |  | 83d | start no earlier than 2006-02-01 | C3 | 1360h |  | WLANPNA-st3-CT3 | Pierre-Jean Muller (NEC) | pierre-jean.muller@nectech.fr | Rel-7 | Andrijana | 29.161 |  |
| 218 | 50.2.3 | CT4 aspets for WLAN-PNA | 170d? | 2006-02-01 | 2006-09-26 |  |  |  |  |  | 83d | start no earlier than 2006-02-01 | C4 | 1360h |  | WLANPNA-st3-CT4 | Pierre-Jean Muller (NEC) | pierre-jean.muller@nectech.fr | Rel-7 | Andrijana | 29.234 |  |
| 219 | 51 | **Supporting Globally Routable User Agent URIs in IMS** | 220d? | 2005-11-14 A | 2006-09-15 | 21% | 174.27d? | 2005-10-10 | 2006-10-20 | 0d? | 90d |  | S2 | 2232h | 464h | GURU | Adrian Buckley (Research In Motion) | abuckley@rim.com | Rel-7 | Maurice | 23.8XX, 22.228, 23.228, 23.218, 24.229 |  |
| 220 | 51.1 | TR on GURU | 219d? | 2005-11-14 A | 2006-09-14 | 26% | 161d? |  |  |  | 91d | finish no earlier than 2006-09-14 | S2 | 1752h | 464h | GURU |  |  |  |  |  |  |
| 221 | 51.2 | Stage 2 on GURU | 60d? | 2006-06-26 | 2006-09-15 |  |  |  |  |  | 90d | finish no earlier than 2006-09-15 | S2 | 480h |  | GURU |  |  |  |  |  |  |
| 222 | 52 | ISIM API for Java Card | 200d? | 2005-03-14 A | 2005-12-16 | 90% | 20d? |  |  |  | 285d | finish no earlier than 2005-12-16 | C6 | 1600h | 1440h | APIJAVA | Sebastian Hans, Sun Microsystems Ltd. |  | Rel-7 | Gaby | 31.103, TS 102 241 |  |

Notes:
- 197: Started at GERAN#24
- 198: Started at GERAN#24
- 199: Not started
- 200: Not started
- 201: FS started
- 202: Conditionally, in the event Phase 2 is needed, end is Dec.06
- 203: WID approved SA#28
- 206: Created by MCC to group all VoIMS related items, after consultation of chairs
- 207: WID approved SA#28
- 209: Started
- 213: Placeholder created to Hold SA2 and CT1 BBs
- 214: Approved at SP#29
- 215: Approved at CP#29
- 216: Approved at CP#29
- 217: Approved at CP#29
- 218: Approved at CP#29
- 219: Approved at SP#29

| ID | WBS | Task | Duration | Start | Finish | Complete | Remaining | Baseline start | Baseline finish | Baseline duration | Total slack | Constraint | Resources | Work | Actual work | Text1 | Text6 | Text3 | Text4 | Text5 | Text8 | Text7 |
| --- | --- | --- | --- | --- | --- | --- | --- | --- | --- | --- | --- | --- | --- | --- | --- | --- | --- | --- | --- | --- | --- | --- |
| 223 | 53 | **Rel7 Security enhancements** | 130d? | 2005-09-12 A | 2006-03-10 | 70% | 38.9d? |  |  |  | 225d |  | S3 | 2584h | 1810.81h | SEC7 | Rel-7 |  |  |  |  |  |
| 224 | 53.1 | HTTPS connection between a UICC and a NAF | 1d? | 2005-09-12 A | 2005-09-12 | 90% | 0.1d? |  |  |  | 354d | start no earlier than 2005-09-12 | S3 | 8h | 7.2h | SEC7-HSUN | Rel-7 | 33.222, 24.109, 33.918 | Jacques Seif (Axlato) | JSeif@axalto.com |  |  |
| 225 | 53.2 | 2G GBA: 2G SIM usage in 3GPP GAA framework | 61d? | 2005-09-12 A | 2005-12-05 | 60% | 24.4d? |  |  |  | 294d | finish no earlier than 2005-12-05 | S3 | 488h | 292.8h | SEC7-2GGBA | Rel-7 | 33.220, 33.290 | Silke Holtmanns (Nokia) | Silke.Holtmanns@nokia.com |  |  |
| 226 | 53.3 | Generic Authentication Architecture usage extensions and optimisations | 1d? | 2005-09-12 A | 2005-09-12 | 25% | 0.75d? |  |  |  | 354d | start no earlier than 2005-09-12 | S3 | 8h | 2h | SEC7-GAA2 | Rel-7 | 33.220, 29.109 | Silke Holtmanns (Nokia) | Silke.Holtmanns@nokia.com |  |  |
| 227 | 53.4 | Network Domain Security; SS7 security Gateway (NDS/TCAPsec) | 130d? | 2005-09-12 A | 2006-03-10 | 75% | 32.5d? |  |  |  | 225d | finish no earlier than 2006-03-10 | S3 | 1040h | 780h | SEC7-NDS-TCAPsec | Rel-7 | 33.200, 33.204 | Marc Blommaert (Siemens) | marc.blommaert@siemens.com |  |  |
| 228 | 54 | IMS Service Brokering enhancements | 69d? | 2005-12-07 A | 2006-03-13 A | 100% |  | 2005-11-04 | 2006-06-16 | 161d? |  | finish no earlier than 2006-03-13 | S1 | 552h | 552h | ISB | Rel-7 | 22.228 | John-Luc Bakker (Telcordia) | jbakker@telcordia.com | Michael |  |
| 229 | 55 | Network Composition | 211d? | 2005-12-07 A | 2006-09-27 | 5% | 200.45d? |  |  |  | 82d | finish no earlier than 2006-09-27 | S1 | 1688h | 84.4h | NetComp | Rel-7 | 22.xxx | Joerg Swetina (Siemens) | joerg.swetina@siemens.com |  |  |
| 230 | 56 | Key establishment between a UICC and a terminal | 201.45d? | 2005-12-07 A | 2006-09-28 | 5% | 191.38d? |  |  |  | 81d | finish no earlier than 2006-09-28 | S3 | 1611.6h | 80.58h | KeyEstUTerm | Rel-7 | 33.xxx | Mireille Pauliac (Gemplus) | mireille.pauliac@gemplus.com |  |  |
| 231 | 57 | **Mobile Station Receive Diversity (DARP Phase II)** | 311d? | 2005-11-11 | 2007-01-19 |  |  |  |  |  | 0d |  | GP | 9400h |  | MSRD2 | Rel-7 | 24.008, 45.005, 51.010 | Kent Pedersen, Nokia Corporation (ETSI) | kent.pedersen@nokia.com | Paolo |  |
| 232 | 57.1 | MS conformance test of DARP Phase II (MSRD) | 311d? | 2005-11-11 | 2007-01-19 |  |  |  |  |  | 0d | finish no earlier than 2007-01-19 | GP | 2488h |  | MSRD2-Msconf | Rel-7 | 51.010 | Kent Pedersen, Nokia Corporation (ETSI) | kent.pedersen@nokia.com | Paolo, Stoyan |  |
| 233 | 57.2 | Performance Requirements for Mobile Station Receive Diversity, DARP Phase II | 216d? | 2005-11-11 | 2006-09-08 |  |  |  |  |  | 95d | finish no earlier than 2006-09-08 | GP | 1728h |  | MSRD2-PerfReq | Rel-7 | 45.005 | Kent Pedersen, Nokia Corporation (ETSI) | kent.pedersen@nokia.com | Paolo |  |
| 234 | 57.3 | Capability signalling of Mobile Station Receive Diversity, DARP Phase II | 216d? | 2005-11-11 | 2006-09-08 |  |  |  |  |  | 95d | finish no earlier than 2006-09-08 | GP | 1728h |  | MSRD2-CapSig | Rel-7 | 24.008 | Kent Pedersen, Nokia Corporation (ETSI) | kent.pedersen@nokia.com | Paolo, Gert |  |
| 235 | 57.4 | Test Scenarios for Mobile Station Receive Diversity, DARP Phase II | 121d? | 2005-11-11 | 2006-04-28 |  |  |  |  |  | 190d | finish no earlier than 2006-04-28 | GP | 968h |  | MSRD2-TestSc | Rel-7 | 45.005 | Kent Pedersen, Nokia Corporation (ETSI) | kent.pedersen@nokia.com | Paolo |  |
| 236 | 58 | MBMS User Service Extensions | 261d? | 2005-12-07 | 2006-12-06 |  |  |  |  |  | 32d | finish no earlier than 2006-12-06 | S4 | 2088h |  | MBMSUSE | Rel-7 | 26.346, 26.946 | Thorsten Lohmar (Ericsson) | Thorsten.Lohmar@ericsson.com | Paolo |  |
| 237 | 59 | IMS Support of Conferencing and Messaging Group Management | 90d? | 2005-11-04 A | 2006-03-09 | 71% | 26d? |  |  |  | 226d | start no earlier than 2005-11-04 | C1 | 720h | 512h | IMSconf | Rel-7 |  | Keith Drage (Lucent) |  | Andrijana |  |
| 238 | 60 | (Small) Technical Enhancements and Improvements for Rel-7 | 400d? | 2005-06-06 | 2006-12-15 |  |  |  |  |  | 25d | finish no earlier than 2006-12-15 | All | 3200h |  | TEI7 | Rel-7 |  |  |  |  |  |
| 239 | 61 | **Selective Disabling of UE Capabilities** | 489.36d? | 2005-01-24 A | 2006-12-08 A | 100% |  | 2005-01-24 | 2006-12-08 | 489.36d? |  |  | S1 | 8308.8h | 8308.8h | SDoUE | Rel-7 | 22.xxx | Nigel Barnes (Motorola Ltd) | Nigel.Barnes@motorola.com | Michael | TSG |
| 240 | 61.1 | Stage 1 | 393.6d? | 2005-01-24 A | 2006-12-08 A | 100% |  | 2005-01-24 | 2006-12-08 | 393.6d? |  | finish no earlier than 2006-12-08 | S1 | 3148.8h | 3148.8h | SDoUE-CRs | Rel-7 | 22.011 | Nigel Barnes (Motorola Ltd) | Nigel.Barnes@motorola.com | Michael | TSG |
| 241 | 61.2 | TR on different possible architectures | 195d? | 2005-03-21 A | 2005-12-16 A | 100% |  | 2005-03-21 | 2005-12-16 | 195d? |  | finish no earlier than 2005-12-16 | S2 | 1560h | 1560h | SDoUE | Rel-7 | 23.805 |  |  | Maurice |  |
| 242 | 62 | **Personal Network Management (PNM)** | 276d? | 2005-07-11 A | 2006-07-31 | 71% | 79.75d? | 2005-07-11 | 2005-12-08 | 101.2d? | 124d |  | S1 | 5689.6h | 4045.65h | PNPAN | Rel-7 |  | Armin Toepfer, Vodafone | armin.toepfer@vodafone.com | Mike |  |
| 243 | 62.1 | Study of PNPAM | 167d? | 2005-07-11 A | 2006-02-28 A | 100% |  |  |  |  |  | start no earlier than 2005-07-11 | S1 | 1336h | 1336h |  |  |  |  |  |  |  |
| 244 | 62.2 | Stage 1 of PNPAM | 276d? | 2005-07-11 A | 2006-07-31 | 54% | 128d? |  |  |  | 124d | start no earlier than 2005-07-11 | S1 | 2208h | 1184h |  |  | 22.259 |  |  |  |  |
| 245 | 63 | Multimedia Telephony Capabilities for IMS | 268.2d? | 2005-07-11 A | 2006-07-31 | 52% | 128d? | 2005-07-11 | 2005-12-08 | 101.2d? | 124d | finish no earlier than 2005-12-08 | S1 | 2145.6h | 1121.6h | MITE | Rel-7 |  | Peter Bleckert, Ericsson | peter.bleckert @ericsson.com | Mike |  |
| 246 | 64 | **Multimedia interworking between IMS and CS networks** | 181d? | 2005-09-23 A | 2006-06-02 | 71% | 52.73d? | 2005-09-23 | 2006-06-02 | 181d? | 165d |  | C3 | 3287.99h | 1347.43h | MIW-IMS | Rel-7 | 29.163 | Nico Gabriele, Vodafone UK | nico.gabriele@vodafone.com | Seung Don |  |
| 247 | 64.1 | Stages 1 and 2 defined in earlier Release | 49d? | 2005-09-23 A | 2005-11-30 A | 100% |  |  |  |  |  | start no earlier than 2005-09-23 | C3 | 392h | 392h |  |  |  |  |  |  |  |
| 248 | 64.2 | Stage 3 | 181d? | 2005-09-23 A | 2006-06-02 | 63% | 67d? |  |  |  | 165d | start no earlier than 2005-09-23 | C3 | 1448h | 912h |  |  |  |  |  |  |  |

Notes:
- 239: Moved from FS section Feb 06
- 240: Moved from FS section Feb 06
- 241: Moved from FS section Feb 06
- 242: Moved from FS section Feb 06
- 243: Moved from FS section Feb 06
- 244: Moved from FS section Feb 06
- 245: Moved from FS section Feb 06
- 246: Moved from FS section Feb 06
- 247: Moved from FS section Feb 06

| ID | WBS | Task | Duration | Start | Finish | Complete | Remaining | Baseline start | Baseline finish | Baseline duration | Total slack | Constraint | Resources | Work | Actual work | Text1 | Text3 | Text4 | Text5 | Text6 | Text8 | Text12 | Text7 |
| --- | --- | --- | --- | --- | --- | --- | --- | --- | --- | --- | --- | --- | --- | --- | --- | --- | --- | --- | --- | --- | --- | --- | --- |
| 249 | 65 | **Enhancements to support QoS provisioning over 3GPP/WLAN Interworking** | 340d? | 2005-03-14 A | 2006-06-30 | 68% | 108d? | 2005-03-14 | 2006-09-11 | 391d? | 145d |  | S2 | 5440h | 3712h | WLAN-QOS | 23.836 | Osok Song, Samsung | osok.song@samsung.com | Rel-7 | Maurice |  |  |
| 250 | 65.1 | TR on support of QoS on WLAN | 232d? | 2005-03-14 A | 2006-01-31 A | 100% |  |  |  |  |  | start no earlier than 2005-03-14 | S2 | 1856h | 1856h |  |  |  |  |  |  |  |  |
| 251 | 65.2 | Stage 2 on support of QoS over 3GPP/WLAN interworking | 108d? | 2006-02-01 | 2006-06-30 |  |  |  |  |  | 145d | start no earlier than 2006-02-01 | S2 | 864h |  |  |  |  |  |  |  |  |  |
| 252 | 66 | **DELETE - PS domain and IMS support for IMS Emergency sessions** | 185d? | 2005-10-10 | 2006-06-23 |  |  | 2005-10-10 | 2006-06-23 | 185d? | 150d |  | S2 | 1940.97h |  | IMS-EMER | 23.867, TS 23.abc, 23.060, 23.002, 23.271 | Curt Wong (Nokia) | curt.c.wong@nokia.com | Rel-7 | Maurice | SP-30 |  |
| 253 | 66.1 | DELETE IMS aspects to support IMS Emergency sessions | 121.31d? | 2005-10-10 | 2006-06-23 |  |  | 2005-10-10 | 2006-06-23 | 121.31d? | 150d | finish no earlier than 2006-06-23 | S2 | 970.48h |  | IMS-EMER | 23.867, TS 23.abc, 23.060, 23.002, 23.271 | Curt Wong (Nokia) | curt.c.wong@nokia.com | Rel-7 | Maurice | SP-30 | TSG |
| 254 | 66.2 | DELETE PS domain aspects to support IMS Emergency sessions | 121.31d? | 2005-10-10 | 2006-06-23 |  |  | 2005-10-10 | 2006-06-23 | 121.31d? | 150d | finish no earlier than 2006-06-23 | S2 | 970.48h |  | IMS-EMER | 23.867, TS 23.abc, 23.060, 23.002, 23.271 | Curt Wong (Nokia) | curt.c.wong@nokia.com | Rel-7 | Maurice | SP-30 | TSG |
| 255 | 67 | DELETED- Covered by SI - Personal Network (PN) and Personal Area Network (PAN) | 101.2d? | 2005-07-11 A | 2005-12-08 | 70% | 30.36d? | 2005-07-11 | 2005-12-08 | 101.2d? | 291d | finish no earlier than 2005-12-08 | S1 | 809.6h | 566.72h | PNPAN |  | Armin Toepfer, Vodafone | armin.toepfer@vodafone.com | Rel-7 | Mike | SP-30 |  |
| 256 | 68 | DELETED- Covered by SI - Multimedia Telephony Capabilities for IMS | 101.2d? | 2005-07-11 A | 2005-12-08 | 70% | 30.36d? | 2005-07-11 | 2005-12-08 | 101.2d? | 291d | finish no earlier than 2005-12-08 | S1 | 809.6h | 566.72h | MITE |  | Peter Bleckert, Ericsson | peter.bleckert @ericsson.com | Rel-7 | Mike | SP-30 |  |
| 257 | 69 | DELETED- Covered by SI - Transferring of emergency Call data | 109d? | 2005-07-11 A | 2005-12-08 | 70% | 32.7d? | 2005-07-11 | 2005-12-08 | 109d? | 291d | finish no earlier than 2005-12-08 | S1 | 872h | 610.4h | eCALL |  | Steve Vardy, (Motorola S.A.S) | steven.vardy@motorola.com | Rel-7 | Mike | SP-30 |  |
| 258 | 70 | DELETED- Covered by SI - MBMS Enhancements | 109d? | 2005-07-11 A | 2005-12-08 | 20% | 87.2d? | 2005-07-11 | 2005-12-08 | 109d? | 291d | finish no earlier than 2005-12-08 | S1 | 872h | 174.4h | MBMSE |  | Liu Hong, China Mobile | liuhongyfw@chinamobile.com | Rel-7 | Mike | SP-30 |  |
| 259 | 71 | Rel-7 Feasibility Studies listed below | 1d? | 2000-01-03 | 2000-01-03 |  |  | 2000-01-03 | 2000-01-03 | 1d? | 1839d |  | CT;RAN;SA | 8h |  |  |  |  |  | Rel-7 |  |  |  |
| 260 | 72 | Study Item on IMS enhancements and optimisations for real time communication. | 234d? | 2005-10-10 A | 2006-08-31 | 44% | 131d? |  |  |  | 101d | start no earlier than 2005-10-10 | S2 | 1872h | 824h | IMS-RT | 23.818 | Stephen Terrill (Ericsson) | stephen.terrill@ericsson.com |  | Maurice |  |  |
| 261 | 73 | Behaviour of Multi system UEs | 480d? | 2004-06-28 A | 2006-04-28 | 87% | 62d? | 2004-06-28 | 2005-03-16 | 188d? | 190d | start no earlier than 2004-06-28 | S1 | 3840h | 3344h | BMSU | 22.936 | D Williams (QUALCOMM) | dwilliams@qualcomm.com | Rel-7 | Michael |  | TSG |
| 262 | 74 | **FS on IMS with real time services deployment** | 384d? | 2004-06-28 A | 2005-12-15 | 99% | 0d? | 2004-06-28 | 2005-12-15 | 384d? | 0d |  | S1 | 8672h | 6304.24h | IRTSD |  |  |  | Rel-7 | Maurice |  | TSG |
| 263 | 74.1 | Feasibility Study on Combining CS calls and IMS sessions | 384d? | 2004-06-28 A | 2005-12-15 A | 100% |  | 2004-06-28 | 2005-12-15 | 384d? |  | start no earlier than 2004-06-28 | S1 | 3072h | 3072h | IRTSD-CS_IMS | 22.979, 23.899 |  |  | Rel-7 | Michael |  | TSG |
| 264 | 74.2 | TR on Stage 2 (IMS services using CS bearers) | 316d? | 2004-06-28 A | 2005-09-12 A | 100% |  | 2004-06-28 | 2005-09-12 | 316d? |  | finish no earlier than 2005-09-12 | S2 | 2528h | 2528h | IRTSD-IMSCS | 23.899 | Mark Watson (Nortel Networks) |  | Rel-7 | Maurice |  | TSG |
| 265 | 75 | TR on CSI interworking related aspects | 190d? | 2006-01-09 A | 2006-09-29 | 20% | 152d? |  |  |  | 80d | start no earlier than 2006-01-09 | S2 | 1520h | 304h | IRTSD-IMSCS |  | Osok Song (Samsung) |  | Rel-7 | Maurice |  |  |
| 266 | 76 | **All-IP Network (AIPN)** | 448d? | 2004-06-28 A | 2006-03-15 A | 100% |  | 2004-06-28 | 2006-03-15 | 448d? |  |  | S1 | 8672h | 8672h | AIPN | 22.978 | Chris Sachno (NTT DoCoMo) | c.masyu@nttdocomo.co.jp | Rel-7 | Michael |  | TSG |
| 267 | 76.1 | All-IP Network Feasibility Study | 188d? | 2004-06-28 A | 2005-03-16 A | 100% |  | 2004-06-28 | 2005-03-16 | 188d? |  | start no earlier than 2004-06-28 | S1 | 1504h | 1504h | AIPFS | 22.978 | Chris Sachno (NTT DoCoMo) | c.masyu@nttdocomo.co.jp | Rel-7 | Michael |  | TSG |
| 268 | 76.2 | Stage1 | 448d? | 2004-06-28 A | 2006-03-15 A | 100% |  | 2004-06-28 | 2006-03-15 | 448d? |  | finish no earlier than 2006-03-15 | S1 | 3584h | 3584h | AIPN | 22.258 | Chris Sachno (NTT DoCoMo) | c.masyu@nttdocomo.co.jp | Rel-7 | Michael |  | TSG |
| 269 | 77 | **3GPP System Architecture Evolution** | 466d? | 2004-12-03 A | 2006-09-15 | 66% | 156.94d? | 2004-12-03 | 2006-06-16 | 401d? | 90d |  | S2 | 9144h | 6064.48h | SAE |  |  |  | Rel-7 |  |  | TSG |
| 270 | 77.1 | Stage 2 Interim conclusion for RAN Work to start | 211d? | 2004-12-03 A | 2005-09-23 A | 100% |  | 2004-12-03 | 2005-09-23 | 211d? |  | finish no earlier than 2005-09-23 | S2 | 1688h | 1688h | SAE | 23.882 |  |  | Rel-7 |  |  |  |
| 271 | 77.2 | Stage 2 Feasibility study on 3GPP architectural development | 466d? | 2004-12-03 A | 2006-09-15 | 51% | 228d? | 2004-12-03 | 2006-06-16 | 401d? | 90d | finish no earlier than 2006-09-15 | S2 | 3728h | 1904h | SAE | 23.882 |  |  | Rel-7 |  |  |  |
| 272 | 78 | FS on Performance Evaluation of the UE behaviour in high speed trains with speeds up to 350 kmph | 261d? | 2005-03-15 A | 2006-03-15 | 80% | 52.2d? | 2005-03-15 | 2006-03-15 | 261d? | 223d | finish no earlier than 2006-03-15 | R4 | 2088h | 1670.4h | RANFS-HSTrains |  | Mike Vogel | Mike.vogel@vodafone.com | Rel-7 | MCC_RAN |  | TSG |
| 273 | 79 | FS of enhanced support of Video Telephony | 481d? | 2004-08-27 A | 2006-06-30 | 35% | 312.65d? | 2004-08-27 | 2005-11-11 | 316d? | 145d | finish no earlier than 2006-06-30 | GP | 3848h | 1346.8h | VIDGER |  | Stefan Eriksson, Ericsson | stefan.g.eriksson@ericsson.com | Rel-7 | Paolo |  | TSG |
| 274 | 80 | FS on Evolved UTRA and UTRAN | 130d? | 2004-12-15 A | 2005-06-15 | 30% | 91d? | 2004-12-15 | 2005-06-15 | 130d? | 418d | finish no earlier than 2005-06-15 | RP | 1040h | 312h | RANFS-Evo |  | Takehiro Nakamura (NTT DoCoMo) | nakamurata@NTTDOCOMO.CO.JP | Rel-7 | MCC_RAN |  | TSG |

Notes:
- 249: Moved from FS section Feb 06
- 252: Approved at SP#29
- 253: Approved at SP#29
- 254: Approved at SP#29
- 260: Approved at SP#29. To be shown as feature - END Sept 06
- 261: The WID still calls it a BB, not a Feature.
- 270: RAN work started
- 273: FS started

| ID | WBS | Task | Type | Duration | Start | Finish | Complete | Remaining | Baseline start | Baseline finish | Baseline duration | Total slack | Constraint | Resources | Work | Actual work | Text1 | Text4 | Text5 | Text6 | Text7 | Text8 | Text3 | Text12 |
| --- | --- | --- | --- | --- | --- | --- | --- | --- | --- | --- | --- | --- | --- | --- | --- | --- | --- | --- | --- | --- | --- | --- | --- | --- |
| 275 | 81 | **Study on Videotelephony teleservice** |  | 231d? | 2005-03-01 A | 2006-01-17 A | 100% |  | 2005-03-15 | 2006-12-06 | 452d? |  |  | S1 | 3696h | 3696h | VidTel | Kurt Bischinger (T-Mobile) | kurt.bischinger@t-mobile.at | Rel-7 | TSG | Michael |  |  |
| 276 | 81.1 | Study on Videotelephony service requirements |  | 231d? | 2005-03-01 A | 2006-01-17 A | 100% |  | 2005-03-15 | 2006-12-06 | 452d? |  | start no earlier than 2005-03-01 | S1 | 1848h | 1848h | VidTel | Kurt Bischinger (T-Mobile) | kurt.bischinger@t-mobile.at | Rel-7 | TSG | Michael | 22.903 |  |
| 277 | 82 | **Study of Network Selection Principles** |  | 193d? | 2005-03-15 A | 2005-12-08 | 99% | 0d? | 2005-03-15 | 2005-12-08 | 193d? | 0d |  | S1 | 3088h | 2658.02h | NetSel | Chris Friel (O2) | chris.friel@o2.com | Rel-7 | TSG | Michael |  |  |
| 278 | 82.1 | Review of Network Selection Principles |  | 193d? | 2005-03-15 A | 2005-12-08 A | 100% |  | 2005-03-15 | 2005-12-08 | 193d? |  | finish no earlier than 2005-12-08 | S1 | 1544h | 1544h | NetSel | Chris Friel (O2) | chris.friel@o2.com | Rel-7 | TSG | Michael | 22.811 |  |
| 279 | 83 | FS on Continuous connectivity for packet data users |  | 132d? | 2005-03-15 A | 2005-09-15 A | 100% |  | 2005-03-15 | 2005-09-15 | 132d? |  | finish no earlier than 2005-09-15 | R1 | 1056h | 1056h | RANFS-cont-packet | Joerg Gustrau | joerg.gustrau@siemens.com | Rel-7 | TSG | MCC_RAN |  |  |
| 280 | 84 | FS on UTRA Tower Mounted Amplifier (FDD) |  | 195d? | 2005-06-15 A | 2006-03-15 | 10% | 175.5d? | 2005-06-15 | 2006-03-15 | 195d? | 223d | finish no earlier than 2006-03-15 | R4 | 1560h | 156h | RANFS-TMA | Klas Sjerling | Klas.Sjerling@ericsson.com | Rel-7 | TSG | MCC_RAN |  |  |
| 281 | 85 | Multimedia Priority Service |  | 851d? | 2003-03-28 A | 2006-06-30 | 87% | 107d? | 2003-03-28 | 2004-12-16 | 450d? | 145d | finish no earlier than 2005-12-16 | S1 | 6808h | 5952h | PRIOR-MM | Jim Garrahan (Telcordia) | jgarraha@telcordia.com | Rel-6 |  | Michael | 22.953 |  |
| 282 | 86 | Transferring of emergency Call data |  | 190d? | 2005-07-11 A | 2006-03-31 A | 100% |  | 2005-07-11 | 2005-12-08 | 109d? |  | finish no earlier than 2005-12-08 | S1 | 1520h | 1520h | eCALL | Steve Vardy, (Motorola S.A.S) | steven.vardy@motorola.com | Rel-7 |  | Mike |  |  |
| 283 | 87 | MBMS Enhancements |  | 109d? | 2005-07-11 A | 2005-12-08 | 25% | 81.75d? | 2005-07-11 | 2005-12-08 | 109d? | 291d | finish no earlier than 2005-12-08 | S1 | 872h | 218h | MBMSE | Liu Hong, China Mobile | liuhongyfw@chinamobile.com | Rel-7 |  | Mike |  |  |
| 284 | 88 | IMS security extensions |  | 118d? | 2005-06-28 A | 2005-12-08 | 60% | 47.2d? | 2005-06-28 | 2005-12-08 | 118d? | 291d | start no earlier than 2005-06-28 | S3 | 944h | 566.4h | IMS-SE | Bengt Sahlin, Ericsson | Bengt.Sahlin@ericsson.com | Rel-7 |  | Mike |  |  |
| 285 | 89 | Study of a SMS Centre for MT SMS |  | 191d? | 2005-10-07 A | 2006-06-30 | 44% | 107d? | 2005-10-07 | 2006-03-17 | 116d? | 145d | start no earlier than 2005-10-07 | C4 | 1528h | 672h | SMS7 | Nick Russell, Vodafone UK | Nick.Russell@vodafone.com | Rel-7 |  | Kimmo | 23.840 |  |
| 286 | 90 | Study of Customised Alerting Tone (CAT) Requirements |  | 191d? | 2005-10-07 | 2006-06-30 |  |  |  |  |  | 145d | start no earlier than 2005-10-07 | S1 | 1528h |  | CAT |  |  | Rel-7 |  |  |  |  |
| 287 | 91 | Facilitating Machine to Machine Communication in GSM and UMTS (M2M) |  | 161d? | 2005-11-04 A | 2006-06-16 | 25% | 120.75d? |  |  |  | 155d | finish no earlier than 2006-06-16 | S1 | 1288h | 322h | M2M | Juergen Merkel, Siemens AG |  | Rel-7 |  | Michael | 22.868 |  |
| 288 | 92 | FS on Improvement of the Multimedia Broadcast Multicast Service (MBMS) in UTRAN |  | 131d? | 2005-12-15 | 2006-06-15 |  |  |  |  |  | 156d | finish no earlier than 2006-06-15 | R2 | 1048h |  | MBMSImp | YoungDae Lee, LG | leego@lge.com | Rel-7 |  | MCC_RAN |  |  |
| 289 | 93 | FS on Performance Improvements in Small Cells using HSDPA/EDCH |  | 131d? | 2005-12-15 | 2006-06-15 |  |  |  |  |  | 156d | finish no earlier than 2006-06-15 | R4 | 1048h |  | SMALLCELLS | Marc Grant, Cingular | marc.grant@cingular.com | Rel-7 |  | MCC_RAN |  |  |
| 290 | 94 | FS on Further Improved Performance Requirements for UMTS/HSDPA UE (FDD) |  | 262d? | 2005-12-15 | 2006-12-15 |  |  |  |  |  | 25d | finish no earlier than 2006-12-15 | R4 | 2096h |  | HSDPAUE1 | Marc Grant, Cingular | marc.grant@cingular.com | Rel-7 |  | MCC_RAN |  |  |
| 291 | 95 | **Deleted: FS on applicability of GALILEO for LCS** |  | 484d? | 2003-08-25 A | 2005-06-30 |  | 484d? | 2003-08-25 | 2005-06-30 | 484d? | 406d |  | S2 | 3872h | 1000h | Galileo |  |  | Rel-7 |  |  |  | SP-25 |
| 292 | 95.1 | Deleted - TR on Stage 2 | milestone | 0d? | 2005-06-30 A | 2005-06-30 A | 100% |  | 2005-06-30 | 2005-06-30 | 0d? |  | finish no earlier than 2005-06-30 | S2 |  |  | Galileo |  |  | Rel-7 |  |  |  | SP-25 |
| 293 | 95.2 | deleted - GERAN review of the TR | milestone | 0d? | 2003-08-25 | 2003-08-25 |  |  | 2003-08-25 | 2003-08-25 | 0d? | 890d | finish no earlier than 2003-08-25 | GP |  |  | Galileo |  |  | Rel-7 |  |  |  | SP-26 |
| 294 | 16.7 | **Deleted - IMS Local services** |  | 1158d? | 2001-01-01 A | 2005-06-08 | 68% | 367.35d? | 2001-01-01 | 2005-06-08 | 1158d? | 422d |  | S2 | 13072h | 5192.02h | IMSLocal |  |  | Rel-7 |  |  | 23.228 | SP-28 |
| 295 | 16.7.1 | Deleted - Stage 2 |  | 325d | 2001-01-01 A | 2002-03-29 A | 100% |  | 2001-01-01 | 2002-03-29 | 325d |  | start no earlier than 2001-01-01 | S2 | 2600h | 2600h | IMSLocal |  |  | Rel-7 |  |  |  | SP-26 |
| 296 | 96.2 | Delete - Stage 3 for IMS Local services |  | 151d? | 2004-11-10 | 2005-06-08 |  |  | 2004-11-10 | 2005-06-08 | 151d? | 422d | finish no earlier than 2005-06-08 | C1 | 1208h |  | IMSLocal | Keith Drage, Lucent | drage@lucent.com | Rel-7 |  |  |  | SP-25 |
| 297 | 97 | Deleted - IMS Phase 3 | milestone | 0d? | 2005-06-08 A | 2005-06-08 A | 100% |  | 2005-06-08 | 2005-06-08 | 0d? |  | finish no earlier than 2005-06-08 | S2 |  |  |  |  |  | Rel-7 |  |  |  | SP-25 |
| 298 | 98 | Deleted - Improvements of Radio Interface | milestone | 0d? | 2004-09-15 A | 2004-09-15 A | 100% |  | 2004-09-15 | 2004-09-15 | 0d? |  | start no earlier than 2004-09-15 | RP |  |  | RInImp |  | Rel-7 | Rel-7 | TSG | Cesar |  | SP-24 |

Notes:
- 281: Moved from Rel6
- 285: Study WI
- 286: Awaiting MCC SA3 input
- 295: DAB - Not yet required in SA2 as it exists in previous releases
- 298: Stage 2 description of Interim conclusion

| ID | WBS | Task | Type | Duration | Start | Finish | Remaining | Baseline start | Baseline finish | Baseline duration | Total slack | Constraint | Resources | Text6 | Text8 | Text12 | Text3 | Text7 |
| --- | --- | --- | --- | --- | --- | --- | --- | --- | --- | --- | --- | --- | --- | --- | --- | --- | --- | --- |
| 299 | 99 | **Deleted: Generic User Profile Phase 2** |  | 234.4d | 2005-10-06 A | 2006-08-31 | 234.4d | 2005-10-06 | 2006-08-31 | 234.4d | 101.6d |  | C4 | Rel-7 | Gaby | SP-27 |  |  |
| 300 | 30.4 | Deleted - Stage 3 - Common objects | milestone | 0d | 2005-10-06 A | 2006-08-31 | 0d | 2005-10-06 | 2006-08-31 | 0d | 101.6d | finish no earlier than 2005-10-06 | C4 | Rel-7 | Gaby | SP-27 | 24.241 | TSG |

Notes:
- 299: Created at TSG#27 by A. Sultan because of the move to Rel-7 of "Common Objects".
- 300: No progress in CN4#26. This have to be moved to Rel-7. It was deleted from WID
